# 3GPP_Work Plan

Schedule from MS Project, 2000-01-03 to 2005-06-15, A marks actual dates.

## Calendars

- Standard: Mon-Fri 08:00-12:00, 13:00-17:00; Sat-Sun off.

## Resources

| Resource | Cost per use |
| --- | --- |
| NP | -0.02 |
| N1 |  |
| N2 |  |
| N3 |  |
| N4 |  |
| N5 |  |
| TP |  |
| T1 |  |
| T2 |  |
| T3 |  |
| RP |  |
| R1 |  |
| R2 |  |
| R3 |  |
| R4 |  |
| SP |  |
| S1 |  |
| S2 |  |
| S3 |  |
| S4 |  |
| S5 |  |
| PCG |  |
| GP |  |
| No |  |
| CN4 |  |
| ? |  |
| WG G2 |  |
| G2 |  |
| G1 |  |
| G4 |  |
| G3 |  |
| All |  |
| Generic |  |
| MLST |  |
| G5 |  |
| S3, G2 |  |
| WG T2 |  |
| GP,G1 |  |
| G4,G5 |  |
| OMA |  |
| GP-G2 |  |
| Yes |  |

## Schedule

| ID | WBS | Task | Duration | Start | Finish | Complete | Remaining | Baseline start | Baseline finish | Baseline duration | Total slack | Constraint | Resources | Work | Actual work | Text6 | Text9 | Text1 | Text4 | Text5 | Text7 | Text8 | Text11 | Text10 | Text2 | Text3 | Text12 |
| --- | --- | --- | --- | --- | --- | --- | --- | --- | --- | --- | --- | --- | --- | --- | --- | --- | --- | --- | --- | --- | --- | --- | --- | --- | --- | --- | --- |
| 1 | 1 | VERSION 2004 June 8th | 1d | 2000-01-03 | 2000-01-03 |  |  | 2000-01-03 | 2000-01-03 | 1d | 1522d |  |  |  |  | Rel | 2044 |  |  |  |  |  |  |  |  |  |  |
| 2 | 2 | "CTRL + a" to display all the 3GPP fields | 1d | 2000-01-03 | 2000-01-03 |  |  | 2000-01-03 | 2000-01-03 | 1d | 1522d |  |  |  |  |  | 1462 |  |  |  |  |  |  |  |  |  |  |
| 3 | 3 | Content of Rel-6 and after. Not frozen. | 1d | 2000-01-03 | 2000-01-03 |  |  | 2000-01-03 | 2000-01-03 | 1d | 1522d |  |  |  |  | Rel | 2058 |  |  |  |  |  |  |  |  |  |  |
| 5 | 4 | Evolutions of the transport in the UTRAN | 218d | 2003-03-03 | 2003-12-31 |  |  |  |  |  | 480d | start no earlier than 2003-03-03 | RP | 1744h |  | NA | Feat | ETRAN | Francois Courau, Alcatel | francois.courau@alcatel.fr | TSG | MCC_RAN | Generic |  |  |  |  |
| 6 | 8 | **Improvements of Radio Interface** | 1068d | 2000-08-14 A | 2004-09-15 | 78% | 229.66d | 2000-08-14 | 2004-03-19 | 940d? | 194d |  | RP | 38080h | 29691.5h | Rel-6 |  | RInImp |  |  | TSG |  |  |  |  |  |  |
| 7 | 5.1 | Improvement of inter-frequency and inter-system measurement | 968d | 2001-01-01 A | 2004-09-15 | 50% | 484d |  |  |  | 194d | finish no earlier than 2004-09-15 | R1 | 7744h | 3872h | Rel-6 | BB | RInImp-IfIsM | Antti Toskala, Nokia | antti.toskala@nokia.com | TSG | MCC RAN | Active | 1216 |  |  |  |
| 8 | 5.2 | Improving Receiver Performance Requirements for the FDD UE | 401d | 2002-03-08 A | 2003-09-19 A | 100% |  |  |  |  |  | start no earlier than 2002-03-08 | R4 | 3208h | 3208h | Rel-6 | BB | RInImp-UERecPerf | Shimon Moshavi, Intel | shimon.moshavi@INTEL.COM | TSG |  | Active | 1216 |  |  |  |
| 9 | 8.2 | **Base station classification** | 603d | 2000-08-14 A | 2002-12-04 A | 100% |  | 2000-08-14 | 2002-12-04 | 603d |  |  | R4 | 9648h | 9648h | Rel-6 |  | RInImp-BSClass |  |  | TSG |  |  |  |  |  |  |
| 10 | 8.2.1 | FDD Base station classification | 603d | 2000-08-14 A | 2002-12-04 A | 100% |  | 2000-08-14 | 2002-12-04 | 603d |  | finish no earlier than 2002-12-04 | R4 | 4824h | 4824h | Rel-6 | 1476 | RInImp-BSClass-FDD | A. Toskala, Nokia |  | TSG |  |  |  | BaAs |  |  |
| 11 | 5.4 | UMTS-850 | 266d | 2002-12-06 A | 2003-12-12 A | 100% |  |  |  |  |  | finish no earlier than 2003-12-15 | R4 | 2128h | 2128h | Rel-6 | BB | RInImp-UMTS850 | Don Zelmer, Cingular | don.zelmer@cingular.com | TSG | MCC_RAN | Active | 1216 |  |  |  |
| 12 | 5.5 | DS-CDMA introduction in the 800 MHz band | 196d | 2003-03-14 A | 2003-12-12 A | 100% |  |  |  |  |  | finish no earlier than 2003-12-15 | R4 | 1568h | 1568h | Rel-6 | BB | RInImp-UMTS800 | Takehiro Nakamura, NTT DoCoMo | takehiro@wsp.yrp.nttdocomo.co.jp | TSG | MCC_RAN | Active | 1216 |  |  |  |
| 13 | 5.6 | UMTS 1.7/2.1 GHz | 261d | 2003-03-14 A | 2004-03-12 A | 100% |  |  |  |  |  | finish no earlier than 2004-03-15 | R4 | 2088h | 2088h | Rel-6 | BB | RInImp-UMTS1721 | Jussi Numminen, Nokia | jussi.numminen@NOKIA.COM | TSG | MCC RAN | Active | 1216 |  |  |  |
| 14 | 5.7 | **Improved Receiver Performance Requirements for HSDPA** | 197d | 2003-12-15 A | 2004-09-14 | 30% | 137.9d |  |  |  | 195d |  | R4 | 3152h | 472.8h | Rel-6 |  | RInImp-HSPerf | Jussi Numminen, Nokia | jussi.numminen@NOKIA.COM | TSG | MCC RAN |  |  |  |  |  |
| 15 | 5.7.1 | Performance Requirements of Receive Diversity for HSDPA | 197d | 2003-12-15 A | 2004-09-14 | 30% | 137.9d |  |  |  | 195d | start no earlier than 2003-12-15 | R4 | 1576h | 472.8h | Rel-6 |  | RInImp-HSPerf-RxDiv | Takehiro Nakamura (NTT DoCoMo) | takehiro@wsp.yrp.nttdocomo.co.jp | TSG | MCC RAN |  |  |  | TS25.101 |  |
| 16 | 6 | **RAN Feasibility Studies** | 1197d | 2000-08-14 A | 2005-03-15 | 67% | 396.27d |  |  |  | 65d |  | RP | 46152h | 26479.7h | Rel-6 |  |  |  |  |  |  |  |  |  |  |  |
| 17 | 6.1 | FS on Radio link performance enhancements | 1002d | 2000-08-14 A | 2004-06-15 | 70% | 300.6d |  |  |  | 260d | finish no earlier than 2004-06-15 | R1 | 8016h | 5611.2h | Rel-6 | SI | RInImp-Rlperf | Antti Toskala, Nokia Networks | antti.toskala@nokia.com | TSG | MCC_RAN | Active | 1216 |  |  |  |
| 18 | 6.2 | FS on UTRA WideBand Distribution Systems | 852d | 2001-03-12 A | 2004-06-15 | 60% | 340.8d |  |  |  | 260d | finish no earlier than 2004-06-15 | R4 | 6816h | 4089.6h | Rel-6 | SI | RInImp-WDS | Andrea Casini, Tekmar Sistemi | carlo.matarasso@andrew.com | TSG | MCC_RAN | Active | 1216 |  |  |  |
| 19 | 6.3 | FS on Improvement of inter-frequency and inter-system measurements for 1.28 Mcps TDD | 461d | 2001-12-14 A | 2003-09-19 A | 100% |  |  |  |  |  | start no earlier than 2001-12-14 | R1 | 3688h | 3688h | Rel-6 | SI | RInImp-IfIsMLCR | Li Xiao Qiang, SAMSUNG | xqli@samsung.co.kr | TSG |  | Active | 1216 |  |  | 10 |
| 20 | 6.4 | FS for the analysis of OFDM for UTRAN enhancement | 526d | 2002-06-10 A | 2004-06-14 | 75% | 131.5d |  |  |  | 261d | start no earlier than 2002-06-10 | R1 | 4208h | 3156h | Rel-6 | SI | RInImp-FSOFDM | Sarah Boumendil, Nortel | boumendi@nortelnetworks.com | TSG | MCC_RAN | Active | 1216 |  |  | 11 |
| 21 | 6.5 | FS on Uplink Enhancements for Dedicated Transport Channels | 396d | 2002-09-06 A | 2004-03-12 A | 100% |  |  |  |  |  | finish no earlier than 2004-03-12 | R1 | 3168h | 3168h | Rel-6 | SI | RInImp-FSUpDTrCh | Karri Ranta-aho, Nokia | Karri.Ranta-aho@nokia.com | TSG | MCC_RAN | Active | 1216 |  |  | 12 |
| 22 | 6.6 | FS on Analysis on Higher Chip Rates for UTRA TDD evolutions | 462d | 2002-09-06 A | 2004-06-14 | 80% | 92.4d |  |  |  | 261d | finish no earlier than 2004-06-14 | R1 | 3696h | 2956.8h | Rel-6 | SI | RInImp-FSVHCRTDD | Tim Wilkinson, IPWireless | mbeale@ipwireless.com | TSG | MCC_RAN | Active | 1216 |  |  | 13 |
| 23 | 6.7 | FS on Low Output Powers for general purpose FDD BSs | 128d | 2003-06-13 A | 2004-03-12 A | 100% |  |  |  |  |  | finish no earlier than 2004-03-12 | R3 | 1024h | 1024h | Rel-6 | SI | RInImp-FSLoPw | Ana Burgos, Telefonica | burgos_a@tsm.es | TSG | MCC_RAN | Active | 1216 |  |  | 14 |
| 24 | 6.8 | FS on Uplink enhancements for UTRA TDD | 333d | 2003-06-06 A | 2004-09-14 | 10% | 299.7d |  |  |  | 195d | finish no earlier than 2004-09-14 | R1 | 2664h | 266.4h | Rel-6 | SI | RInImp-FSUpEnhTDD | Marian Rudolf, Interdigital | Marian.Rudolf@InterDigital.com | TSG | MCC_RAN | Active | 1216 |  |  | 15 |
| 25 | 8.8 | FS on UE antenna efficiency test methods performance requirements (2) | 131d | 2002-03-08 A | 2002-09-06 A | 100% |  | 2002-03-08 | 2002-09-06 | 131d |  | finish no earlier than 2002-09-06 | R4 | 1048h | 1048h | Rel-6 |  | RInImp-UEAnTM2 | Alf Ahlström, Allgon |  | TSG |  |  |  |  |  |  |
| 26 | 9.4 | FS on the evolution of the UTRAN architecture | 657d | 2002-09-09 A | 2005-03-15 | 28% | 473.04d | 2002-09-09 | 2003-12-19 | 335d | 65d | finish no earlier than 2005-03-15 | R3 | 5256h | 1471.68h | Rel-6 |  | RANimp-FSEvo | Woonhee Hwang, Nokia | Antti.Toskala@nokia.com | TSG | MCC_RAN |  |  |  |  |  |

Notes:
- 5: Generic feature
- 6: This is a generic feature without particular end date
- 25: The RInImp-UEAnTM FS was re-opened at TSG RAN#15 upon request from WG4
- 26: Work stopped until completion of MBMS in RAN3

| ID | WBS | Task | Duration | Start | Finish | Complete | Remaining | Baseline start | Baseline finish | Baseline duration | Total slack | Constraint | Resources | Work | Actual work | Text1 | Text4 | Text5 | Text6 | Text7 | Text8 | Text9 | Text10 | Text11 | Text3 | Text12 | Text2 |
| --- | --- | --- | --- | --- | --- | --- | --- | --- | --- | --- | --- | --- | --- | --- | --- | --- | --- | --- | --- | --- | --- | --- | --- | --- | --- | --- | --- |
| 27 | 8.5 | **Multiple Input Multiple Output antennas (MIMO)** | 523d? | 2003-03-14 A | 2005-03-15 | 16% | 437.84d? | 2003-03-14 | 2004-12-17 | 461d? | 65d |  | R1 | 16256h | 4064.8h | MIMO | Howard Huang, Lucent | hchuang@lucent.com | Rel-6 | TSG | MCC_RAN | 2468 |  |  |  |  |  |
| 28 | 7.1 | MIMO - Physical layer | 393d? | 2003-09-12 A | 2005-03-15 | 50% | 196.5d? | 2003-03-14 | 2004-03-19 | 266d? | 65d | finish no earlier than 2004-09-14 | R1 | 3144h | 1572h | MIMO-Phys | Howard Huang, Lucent | hchuang@lucent.com | Rel-6 | TSG | MCC RAN |  |  |  |  |  |  |
| 29 | 7.2 | MIMO - Layer 2,3 aspects | 329d? | 2003-09-12 | 2004-12-15 |  |  | 2003-09-12 | 2004-03-19 | 136d? | 129d | finish no earlier than 2004-12-15 | R2 | 2632h |  | MIMO-L23 | Howard Huang, Lucent | hchuang@lucent.com | Rel-6 | TSG | MCC RAN |  |  |  |  |  |  |
| 30 | 7.3 | MIMO - Iub/Iur Protocol Aspects | 459d? | 2003-03-14 | 2004-12-15 |  |  | 2003-03-14 | 2003-09-19 | 136d? | 129d | finish no earlier than 2004-12-15 | R3 | 3672h |  | MIMO-IurIub | Howard Huang, Lucent | hchuang@lucent.com | Rel-6 | TSG | MCC RAN |  |  |  |  |  |  |
| 31 | 7.4 | MIMO - RF Radio Transmission/Reception, System Performance Requirements and Conformance Testing | 328d? | 2003-12-12 A | 2005-03-15 | 15% | 278.8d? | 2003-12-12 | 2004-12-17 | 266d? | 65d | finish no earlier than 2005-03-15 | R4 | 2624h | 393.6h | MIMO-RF | Man Hung Ng, Lucent | ngm@lucent.com | Rel-6 | TSG | MCC RAN |  |  |  |  |  |  |
| 32 | 8 | **FDD Enhanced Uplink** | 327d | 2004-03-15 | 2005-06-15 |  |  |  |  |  | 0d |  | RP | 9968h |  | EDCH | Joakim Bergström (Ericsson) |  |  | TSG | MCC RAN | Feat | 20003 | Active |  |  |  |
| 33 | 8.1 | EDCH - Stage 2 | 1d | 2004-03-15 | 2004-03-15 |  |  |  |  |  | 326d | start no earlier than 2004-03-15 | R2 | 8h |  | EDCH-Stage2 |  |  |  | TSG |  |  |  |  | New TR |  |  |
| 34 | 8.2 | EDCH - Physical Layer | 197d | 2004-03-15 | 2004-12-15 |  |  |  |  |  | 130d | finish no earlier than 2004-12-15 | R1 | 1576h |  | EDCH-Phys | Karri Ranta-aho (Nokia) |  |  | TSG | MCC RAN | BB | 20003 | Active | TS25.211, 25.212, 25.213, 25.214, 25.215 | 26 |  |
| 35 | 8.3 | EDCH - Layer 2 and 3 Protocol Aspects | 197d | 2004-03-15 | 2004-12-15 |  |  |  |  |  | 130d | finish no earlier than 2004-12-15 | R2 | 1576h |  | EDCH-L23 | Joakim Bergström (Ericsson) |  |  | TSG | MCC RAN | BB | 20003 | Active | TS25.301, 25.302, 25.306, 25.321, 25.331 | 27 |  |
| 36 | 8.4 | EDCH - UTRAN Iub/Iur Protocol Aspects | 197d | 2004-03-15 | 2004-12-15 |  |  |  |  |  | 130d | finish no earlier than 2004-12-15 | R3 | 1576h |  | EDCH-IurIub | Saso Stojanovski (Nortel) |  |  | TSG | MCC RAN | BB | 20003 | Active | TS25.401, 25.420, 25.423, 25.430, 25.433 | 28 |  |
| 37 | 8.5 | EDCH - RF Radio Transmission/ Reception, System Performance Requirements and Conformance Testing | 327d | 2004-03-15 | 2005-06-15 |  |  |  |  |  | 0d | finish no earlier than 2005-06-15 | R4 | 2616h |  | EDCH-RF | Thomas Unshelm (Ericsson) |  |  | TSG | MCC RAN | BB | 20003 | Active | TS25.101, 25.104, 25.133, 25.141 | 29 |  |
| 38 | 9 | **RAN improvements** | 592d? | 2002-09-09 A | 2004-12-15 | 43% | 336.57d? | 2001-12-14 | 2004-03-19 | 591d? | 130d |  | RP | 31096h | 11395.6h | RANimp |  |  | Rel-6 | TSG | MCC_RAN |  |  |  |  |  |  |
| 39 | 9.2 | **RAB support enhancement** | 458d? | 2003-03-14 A | 2004-12-15 | 13% | 396.52d? | 2003-03-14 | 2004-03-19 | 266d? | 130d |  | R2 | 10488h | 1128.8h | RANimp-RABSE | Juha Mikola, Nokia | juha.mikola@nokia.com | Rel-6 | TSG | MCC RAN | 624 |  |  |  |  | BaAS |
| 40 | 9.1.1 | Iu enhancements for IMS support in RAN | 458d? | 2003-03-14 A | 2004-12-15 | 25% | 343.5d? | 2003-03-14 | 2004-03-19 | 266d? | 130d | finish no earlier than 2004-12-15 | R3 | 3664h | 916h | RANimp-RABSE-IuEnhIMS | Phillipe Godin, Nortel | Philippe.Godin@nortelnetworks.com | Rel-6 | TSG | MCC RAN |  |  |  |  |  |  |
| 41 | 9.1.2 | Optimisation of downlink channelisation code utilisation | 198d | 2004-03-12 | 2004-12-15 |  |  |  |  |  | 130d | finish no earlier than 2004-12-15 | R1 | 1584h |  | RANimp-RABSE-CodeOptFDD | Sarah Boumendil (Nortel Networks) | boumendi@nortelnetworks.com |  | TSG | MCC RAN | WT | 624 | Active |  |  |  |
| 42 | 9.1.3 | Optimisation of channelisation code utilisation for TDD | 197d | 2004-03-15 | 2004-12-15 |  |  |  |  |  | 130d | finish no earlier than 2004-12-15 | R1 | 1576h |  | RANimp-RABSE-CodeOptTDD | Nicholas Anderson (IPWireless) |  |  | TSG | MCC RAN | WT | 624 | Active |  |  |  |
| 43 | 9.1 | Beamforming Enhancements | 66d | 2003-09-19 A | 2003-12-19 A | 100% |  | 2001-12-14 | 2003-09-19 | 461d |  | finish no earlier than 2004-03-12 | R1 | 528h | 528h | RANimp-BFE | Jussi Kähtävä, Nokia | jussi.kahtava@nokia.com | Rel-6 | TSG | MCC_RAN |  |  |  |  |  |  |
| 44 | 9.3 | **Rel6 RRM optimization for Iur and Iub** | 126d | 2003-09-19 A | 2004-03-12 | 99% | 0d | 2002-12-06 | 2003-09-19 | 206d? | 0d |  | R3 | 2016h | 1008h | RANimp-RRMopt | Gert-Jan van Lieshout, Ericsson | Gert-Jan.van.Lieshout@eln.ericsson.se | Rel-6 | TSG | MCC_RAN |  |  |  |  |  | BaAS |
| 45 | 9.3.1 | Improved access to User Equipment (UE) measurement data for Controlling Radio Network Controller (CRNC) to support Time Division Duplex (TDD) Radio Resource Management (RRM) | 126d | 2003-09-19 A | 2004-03-12 A | 100% |  |  |  |  |  | finish no earlier than 2004-03-15 | R3 | 1008h | 1008h | RANimp-RRMopt-UEMsD | Jim Miller, Interdigital | jim.miller@interdigital.com | Rel-6 | TSG | MCC RAN | WT | 23012 | Active | TS25.423 | 22 |  |
| 46 | 9.4 | **Remote Control of Electrical Tilting Antennas** | 395d? | 2003-03-14 A | 2004-09-16 | 36% | 254.44d? | 2003-03-14 | 2003-12-05 | 191d? | 193d |  | R3 | 7472h | 2658.87h | RANimp-TiltAnt | Andreas Hauser, Vodafone | Andreas.Hauser@vodafone.com | Rel-6 | TSG | MCC_RAN |  |  |  |  |  |  |
| 47 | 9.4.1 | RAN aspects | 394d? | 2003-03-14 A | 2004-09-15 | 45% | 216.7d? | 2003-03-14 | 2003-12-05 | 191d? | 194d | finish no earlier than 2004-09-15 | R3 | 3152h | 1418.4h | RANimp-TiltAnt | Andreas Hauser, Vodafone | Andreas.Hauser@vodafone.com | Rel-6 | TSG | MCC_RAN |  |  |  |  |  |  |
| 48 | 9.4.2 | OAM&P impacts | 145d | 2004-02-27 A | 2004-09-16 | 10% | 130.5d |  |  |  | 193d | finish no earlier than 2004-09-16 | S5 | 1160h | 116h | RANimp-TiltAnt-OAM | John MUDGE, Vodafone | john.mudge@vodafone.co.uk | Rel-6 | WG | Adrian |  |  |  | 32.804, 32.xyz |  |  |
| 49 | 9.5 | Network Assisted Cell Change (NACC) from UTRAN to GERAN - network-side aspects | 462d? | 2002-09-09 A | 2004-06-15 | 50% | 231d? | 2003-06-13 | 2003-12-19 | 136d? | 260d | finish no earlier than 2004-06-15 | R3 | 3696h | 1848h | RANimp-NACC | Brendan McWilliams, Vodafone | Brendan.McWilliams@gb.vodafone.co.uk | Rel-6 | TSG | MCC_RAN |  |  |  |  |  |  |
| 50 | 9.6 | FS of the improved access to UE measurement data for CRNC to support TDD RRM | 270d? | 2002-12-06 A | 2003-12-18 A | 100% |  | 2002-12-06 | 2003-09-19 | 206d? |  | finish no earlier than 2003-09-19 | R3 | 2160h | 2160h | RANimp-RRMopt-FSUEMsD | Jim Miller, Interdigital | jim.miller@interdigital.com | Rel-6 | TSG |  |  |  |  |  |  |  |

Notes:
- 38: Generic feature
- 39: This is a building block without particular end date
- 40: Completiond 6 months after SA WG2 finishes its block
- 48: az: WID approved at SA5#37 (02/2004)

| ID | WBS | Task | Duration | Start | Finish | Complete | Remaining | Baseline start | Baseline finish | Baseline duration | Total slack | Constraint | Resources | Work | Actual work | Text1 | Text4 | Text6 | Text7 | Text2 | Text3 | Text9 | Text5 | Text8 |
| --- | --- | --- | --- | --- | --- | --- | --- | --- | --- | --- | --- | --- | --- | --- | --- | --- | --- | --- | --- | --- | --- | --- | --- | --- |
| 51 | 10 | **PS domain and IMS impacts for supporting IMS Emergency calls** | 1255d? | 2000-08-14 A | 2005-06-03 | 36% | 799.31d? | 2000-08-14 | 2003-12-12 | 870d? | 7d |  | S2 | 49760h | 15631.8h | EMC1 | Rainer Liebhart | Rel-7 | TSG |  |  |  |  |  |
| 52 | 10.1.1 | Service Requirements for IP-based emergency calls | 985d | 2000-09-18 A | 2004-06-25 A | 100% |  | 2000-09-18 | 2003-06-27 | 725d |  | finish no earlier than 2004-06-25 | S1 | 7880h | 7880h |  |  | Rel-7 |  | CCaR | 22.976 | 1314 |  |  |
| 53 | 10.2 | Stage 2 | 471d? | 2003-02-26 A | 2004-12-15 | 52% | 226.08d? | 2003-02-26 | 2003-09-18 | 147d? | 129d | finish no earlier than 2004-12-15 | S2 | 3768h | 1959.36h |  | Rainer Liebhart, Siemenws | Rel-7 | TSG |  |  |  |  |  |
| 54 | 10.1 | **Emergency Call Enhancements for IP& PS Based Calls – stage 3** | 1255d | 2000-08-14 A | 2005-06-03 | 8% | 1156.47d | 2000-08-14 | 2003-12-12 | 870d | 7d |  | N1 | 28272h | 2219.53h |  | Mr Atle Monrad, Ericsson | Rel-7 |  | CCaR |  | 1653 | Atle.Monrad@eto.ericsson.se |  |
| 55 | 10.1.2 | SIP emergency calls and packet emergency calls signalling flows | 1209d | 2000-10-17 A | 2005-06-03 | 16% | 1015.56d | 2000-10-17 | 2003-12-12 | 824d | 7d | finish no earlier than 2005-06-03 | N1 | 9672h | 1547.52h |  | Mr Atle Monrad, Ericsson | Rel-7 |  | CCaR | TS 24.228 | 1315 | Atle.Monrad@eto.ericsson.se |  |
| 56 | 10.1.5 | Stage 3 for emergency calls and packet emergency calls in general | 1255d | 2000-08-14 | 2005-06-03 |  |  | 2000-08-14 | 2003-12-12 | 870d | 7d | finish no earlier than 2005-06-03 | N1 | 10040h |  |  | Mr Atle Monrad, Ericsson | Rel-7 |  | CCaR | TS 24.229 | 1646 | Atle.Monrad@eto.ericsson.se |  |
| 57 | 12 | **Location Services enhancements 2** | 1090d? | 2000-08-28 A | 2004-10-29 | 55% | 494.42d? | 2000-08-28 | 2004-03-19 | 930d? | 162d |  | S2 | 95856h | 48056.2h | LCS2 |  | Rel-6 | TSG |  |  |  |  | Sang-Ui |
| 58 | 12.1 | **Improvement on Le interface** | 620d? | 2002-06-17 A | 2004-10-29 | 49% | 315.07d? | 2002-06-17 | 2003-12-23 | 397d? | 162d |  | S2 | 10344h | 5087.47h |  |  | Rel-6 | TSG |  |  |  |  |  |
| 59 | 11.1.1 | Stage 2 | 331d? | 2002-06-17 A | 2003-09-22 A | 100% |  | 2002-06-17 | 2003-09-22 | 331d? |  | start no earlier than 2002-06-17 | S2 | 2648h | 2648h |  |  | Rel-6 |  |  |  |  |  |  |
| 60 | 11.1.2 | Stage 3 - impacts MLP (Mobile Location Protocol) | 342d? | 2003-07-10 | 2004-10-29 |  |  | 2003-07-10 | 2003-12-23 | 119d? | 162d | finish no earlier than 2004-10-29 | OMA | 2736h |  |  |  | Rel-6 |  |  |  |  | OMA-LIAISON@mail.openmobilealliance.org |  |
| 61 | 12.2 | **Enhanced support for anonymity and user privacy** | 605d? | 2002-07-08 A | 2004-10-29 | 43% | 346.58d? | 2002-07-08 | 2003-12-23 | 382d? | 162d |  | S2 | 9616h | 4072.03h |  |  | Rel-6 | TSG |  |  |  |  |  |
| 62 | 11.2.1 | Stage 2 | 255d? | 2002-07-08 A | 2003-06-27 A | 100% |  | 2002-07-08 | 2003-06-27 | 255d? |  | finish no earlier than 2003-06-27 | S2 | 2040h | 2040h |  |  | Rel-6 |  |  |  |  |  |  |
| 63 | 11.2.2 | Stage 3 - impacts MLP and RLP | 342d? | 2003-07-10 | 2004-10-29 |  |  | 2003-07-10 | 2003-12-23 | 119d? | 162d | finish no earlier than 2004-10-29 | OMA | 2736h |  |  |  | Rel-6 |  |  |  |  | OMA-LIAISON@mail.openmobilealliance.org |  |
| 64 | 12.3 | **Enhanced inter-GMLC interface** | 615d? | 2002-06-24 A | 2004-10-29 | 56% | 272.21d? | 2002-06-24 | 2003-09-12 | 320d? | 162d |  | S2 | 11960h | 6666.34h |  |  | Rel-6 | TSG |  |  |  |  |  |
| 65 | 11.3.1 | Stage 2 | 315d? | 2002-06-24 A | 2003-09-05 A | 100% |  | 2002-06-24 | 2003-09-05 | 315d? |  | finish no earlier than 2003-09-05 | S2 | 2520h | 2520h |  |  | Rel-6 |  |  |  |  |  |  |
| 66 | 11.3.2 | Stage 3 - definition of RLP and PCP | 565d? | 2002-09-02 A | 2004-10-29 | 31% | 389.5d? | 2002-09-02 | 2003-09-12 | 270d? | 162d | finish no earlier than 2004-10-29 | OMA | 4520h | 1404h |  |  | Rel-6 |  |  |  |  | OMA-LIAISON@mail.openmobilealliance.org |  |
| 67 | 12.4 | **Location Services support for IMS public identities** | 565d? | 2002-09-02 A | 2004-10-29 | 51% | 274.85d? | 2002-09-02 | 2003-12-19 | 340d? | 162d |  | S2 | 9960h | 4833.75h |  |  | Rel-6 | TSG |  |  |  |  |  |
| 68 | 11.4.1 | Stage 2 | 240d? | 2003-02-24 A | 2004-01-23 A | 100% |  | 2003-02-24 | 2003-12-19 | 215d? |  | finish no earlier than 2004-01-23 | S2 | 1920h | 1920h |  |  | Rel-6 |  |  |  |  |  |  |
| 69 | 11.4.2 | Stage 3 - impacts MLP, RLP and PCP | 565d? | 2002-09-02 A | 2004-10-29 | 31% | 391.6d? | 2002-09-02 | 2003-12-19 | 340d? | 162d | finish no earlier than 2004-10-29 | OMA | 4520h | 1387.2h |  |  | Rel-6 |  |  |  |  | OMA-LIAISON@mail.openmobilealliance.org |  |
| 70 | 12.5 | **New area event for location service triggering reports** | 630d? | 2002-06-03 A | 2004-10-29 | 51% | 309.51d? | 2002-06-03 | 2003-12-22 | 406d? | 162d |  | S2 | 11872h | 5707.55h |  |  | Rel-6 | TSG |  |  |  |  |  |
| 71 | 11.5.1 | Stage 2 | 280d? | 2002-06-03 A | 2003-06-27 A | 100% |  | 2002-06-03 | 2003-06-27 | 280d? |  | finish no earlier than 2003-06-27 | S2 | 2240h | 2240h |  |  | Rel-6 |  |  |  |  |  |  |
| 72 | 11.5.2 | Stage 3 for UE-CN signalling | 234d? | 2003-10-09 A | 2004-08-31 | 66% | 79.56d? | 2003-07-10 | 2003-12-22 | 118d? | 205d | finish no earlier than 2004-08-31 | N4 | 1872h | 1235.52h |  |  | Rel-6 |  |  |  |  |  |  |
| 73 | 11.5.3 | Stage 3 - impacts MLP, RLP and PCP | 340d? | 2003-07-14 | 2004-10-29 |  |  | 2003-07-14 | 2003-12-19 | 115d? | 162d | finish no earlier than 2004-10-29 | OMA | 2720h |  |  |  | Rel-6 |  |  |  |  | OMA-LIAISON@mail.openmobilealliance.org |  |
| 74 | 12.6 | **FS on applicability of GALILEO for LCS** | 518d? | 2002-07-08 A | 2004-06-30 | 54% | 236.22d? | 2002-07-08 | 2004-03-19 | 445d? | 249d |  | S2 | 9248h | 3776.48h |  |  | Rel-6 |  |  |  |  |  |  |
| 75 | 11.6.1 | TR on Stage 2 (No contributions received, No feedback from other groups since May) | 518d? | 2002-07-08 A | 2004-06-30 | 67% | 170.94d? | 2002-07-08 | 2004-03-19 | 445d? | 249d | finish no earlier than 2004-06-30 | S2 | 4144h | 2776.48h |  |  | Rel-6 |  |  |  |  |  |  |
| 76 | 11.6.2 | GERAN review of the TR | 120d? | 2003-08-25 | 2004-02-06 |  |  | 2003-08-25 | 2003-12-12 | 80d? | 352d | finish no earlier than 2004-02-06 | GP | 960h |  |  |  | Rel-6 |  |  |  |  |  |  |

Notes:
- 60: Updated according to SP-040232
- 63: Updated according to SP-040232
- 66: Updated according to SP-040232
- 69: Updated according to SP-040232
- 72: 31/10/2003 work has started. Current stage 3 fullfills the requirements of stage 2. ...
- 73: Updated according to SP-040232

| ID | WBS | Task | Duration | Start | Finish | Complete | Remaining | Baseline start | Baseline finish | Baseline duration | Total slack | Constraint | Resources | Work | Actual work | Text1 | Text6 | Text7 | Text8 | Text4 | Text5 | Text9 | Text2 |
| --- | --- | --- | --- | --- | --- | --- | --- | --- | --- | --- | --- | --- | --- | --- | --- | --- | --- | --- | --- | --- | --- | --- | --- |
| 77 | 12.7 | **UE positioning** | 1058d? | 2000-08-28 A | 2004-09-15 | 62% | 402.25d? | 2000-08-28 | 2004-03-19 | 930d? | 194d |  | RP | 25736h | 14022.2h | LCS2-UEpos | Rel-6 | TSG | MCC_RAN |  |  |  |  |
| 78 | 12.7.1 | UE positioning enhancements - other methods | 805d | 2000-08-28 A | 2003-09-26 | 25% | 603.75d | 2000-08-28 | 2003-09-26 | 805d | 447d | start no earlier than 2000-08-28 | R2 | 6440h | 1610h | LCS2-UEpos-enh | Rel-6 | TSG | MCC_RAN | Meik Kottkamp, Siemens | Meik.Kottkamp@siemens.com | 2457 |  |
| 79 | 12.8 | Open SMLC-SRNC Interface within the UTRAN to support UTRAN Rel4 positioning methods | 700d? | 2001-01-15 A | 2003-09-19 A | 100% |  | 2001-01-15 | 2003-09-19 | 700d? |  | finish no earlier than 2003-09-19 | R2 | 5600h | 5600h | LCS-Rel4Pos | Rel-6 | TSG |  | Meik Kottkamp, Siemens | Meik.Kottkamp@siemens.com | 2475 |  |
| 80 | 11.7.3 | A-GPS minimum performance specification | 334d? | 2003-06-06 A | 2004-09-15 | 35% | 217.1d? | 2003-06-06 | 2004-03-19 | 206d? | 194d | finish no earlier than 2004-09-15 | R4 | 2672h | 935.2h | LCS-UEPos-AGPSPerf | Rel-6 | TSG | MCC_RAN | Donglin Shen, AT&T Wireless Services | donglin.shen@attws.com |  |  |
| 81 | 12.7.2 | FS on Enhancements to OTDOA Positioning using advanced blanking methods | 320d | 2002-07-01 A | 2003-09-19 A | 100% |  | 2002-07-01 | 2003-09-19 | 320d |  | finish no earlier than 2003-09-19 | R2 | 2560h | 2560h | LCS2-UEpos-FSBlank | Rel-6 | TSG |  | David Bartlett, Cambridge Positioning Systems | david.bartlett@cursor-system.com |  |  |
| 82 | 14 | **Security enhancements** | 903d? | 2001-01-03 A | 2004-06-18 | 38% | 559.78d? | 2001-01-03 | 2003-03-14 | 573d | 257d |  | S3 | 26984h | 9747.78h | SEC1 | Rel-6 | TSG | Maurice | Peter Howard, Vodafone | Peter.Howard@vodafone.com |  |  |
| 83 | 14.1 | **Enhanced HE control of security (including positive authentication reporting)** | 712d | 2001-01-03 A | 2003-09-25 | 23% | 545d | 2001-01-03 | 2003-03-14 | 573d | 448d |  | S3 | 14064h | 4008h |  | Rel-6 |  |  | Peter Howard, Vodafone | Peter.Howard@vodafone.com | 2026 |  |
| 84 | 14.1.1 | Stage 2 | 378d | 2001-01-03 | 2002-06-14 |  |  | 2001-01-03 | 2002-06-14 | 378d | 782d | finish no earlier than 2002-06-14 | S3 | 3024h |  |  | Rel-6 |  |  |  |  | 2027 |  |
| 85 | 14.1.3 | **Network domain security** | 334d | 2002-06-17 A | 2003-09-25 | 50% | 167d | 2002-06-17 | 2003-03-14 | 195d | 448d |  | S3 | 5344h | 2672h | SEC1-NDS | Rel-6 | TSG |  | Geir M. Køien, Telenor | Geir-myrdahl.koien@telenor.com |  | Sec |
| 86 | 14.1.3.1 | IP network layer security (NDS/IP) | 334d | 2002-06-17 A | 2003-09-25 | 50% | 167d | 2002-06-17 | 2003-03-14 | 195d | 448d | finish no earlier than 2003-09-25 | S3 | 2672h | 1336h | SEC1-NDS-IP | Rel-6 | WG |  |  |  |  |  |
| 87 | 12.2 | Network Domain Security; Authentication Framework (NDS/AF) | 521d? | 2002-02-15 A | 2004-02-13 | 70% | 156.3d? | 2002-02-15 | 2003-12-19 | 481d? | 347d | finish no earlier than 2004-02-13 | S3 | 4168h | 2917.6h | SEC1-NDS-AF | Rel-6 | TSG |  | Tommi Viitanen, Nokia | tommi.viitanen@nokia.com |  |  |
| 88 | 12.3 | Key Management of group keys for Voice Group Call Services | 191d | 2003-09-26 A | 2004-06-18 | 5% | 181.45d |  |  |  | 257d | finish no earlier than 2004-06-18 | S3 | 1528h | 76.4h | SECGKYV | Rel-6 | TSG | Maurice | Benno Tietz, Vodafone D2 | benno.tietz@vodafone.com |  |  |
| 89 | 16 | **IMS Phase 2** | 1112d? | 2000-08-28 A | 2004-11-30 | 65% | 390.14d? | 2000-08-28 | 2003-12-18 | 864d? | 140d |  | S1 | 123088h | 76529.4h | IMS2 | Rel-6 | TSG | Sang-Ui |  |  |  |  |
| 90 | 16.1 | DELETE (covered below) - Stage 2 of IMS Phase 2 | 275d | 2002-09-02 A | 2003-09-19 | 80% | 55d | 2002-09-02 | 2003-09-19 | 275d | 452d | finish no earlier than 2003-09-19 | S2 | 2200h | 1760h |  | Rel-6 |  |  |  |  |  |  |
| 91 | 13.2 | Enhancements to the Cx and Sh interfaces | 323d? | 2003-06-06 A | 2004-08-31 | 60% | 129.2d? | 2003-06-06 | 2003-12-12 | 136d? | 205d | finish no earlier than 2004-08-31 | N4 | 2584h | 1550.4h | IMS2-CCR | Rel-6 | WG |  |  |  |  |  |
| 92 | 16.12 | **IMS Group Management** | 650d? | 2002-03-14 A | 2004-09-08 | 72% | 183.29d? | 2002-03-14 | 2003-12-12 | 457d? | 199d |  | S1 | 11640h | 8357.66h | IMSGM | Rel-6 | TSG |  | Juha Kalliokulju (Nokia) | juha.kalliokulju@nokia.com |  |  |
| 93 | 16.12.1 | Stage 1 - TS on IMS group management | 193d | 2002-03-14 A | 2002-12-09 A | 100% |  | 2002-03-14 | 2002-12-09 | 193d |  | finish no earlier than 2002-12-09 | S1 | 1544h | 1544h |  | Rel-6 | TSG |  | Juha Kalliokulju (Nokia) | juha.kalliokulju@nokia.com |  |  |
| 94 | 13.3.2 | Stage 2 | 158d? | 2003-05-26 A | 2003-12-31 A | 100% |  | 2003-05-26 | 2003-09-23 | 87d? |  | finish no earlier than 2003-12-31 | S2 | 1264h | 1264h |  | Rel-6 |  |  |  |  |  |  |
| 95 | 13.3.3 | Stage 3 for IMS Group management (e.g. chat) | 454d? | 2002-12-13 A | 2004-09-08 | 50% | 227d? | 2002-12-13 | 2003-12-12 | 261d? | 199d | finish no earlier than 2004-09-08 | N1 | 3632h | 1816h |  |  |  |  | Keith Drage, Lucent | drage@lucent.com |  |  |
| 96 | 13.4 | **IMS Conferencing** | 483d? | 2002-11-04 A | 2004-09-08 | 88% | 57.93d? | 2002-11-04 | 2003-12-12 | 290d? | 199d |  | N1 | 9920h | 8730.12h |  | Rel-6 |  |  |  |  |  |  |
| 97 | 13.4.1 | Stage 2 | 303d? | 2002-11-04 A | 2003-12-31 A | 100% |  | 2002-11-04 | 2003-09-26 | 235d? |  | finish no earlier than 2003-12-31 | S2 | 2424h | 2424h |  | Rel-6 |  |  |  |  |  |  |
| 98 | 13.4.2 | Stage 3 | 454d? | 2002-12-13 A | 2004-09-08 | 80% | 90.8d? | 2002-12-13 | 2003-12-12 | 261d? | 199d | finish no earlier than 2004-09-08 | N1 | 3632h | 2905.6h |  |  |  |  | Keith Drage, Lucent | drage@lucent.com |  |  |
| 99 | 16.11 | **IMS Messaging** | 650d? | 2002-03-14 A | 2004-09-08 | 71% | 186.92d? | 2002-03-14 | 2003-12-12 | 457d? | 199d |  | S1 | 17520h | 12481.8h | IMSM | Rel-6 | TSG |  | Juha Kalliokulju (Nokia) | juha.kalliokulju@nokia.com |  |  |
| 100 | 16.11.1 | TR on support of messaging in the IMS | 193d | 2002-03-14 A | 2002-12-09 A | 100% |  | 2002-03-14 | 2002-12-09 | 193d |  | finish no earlier than 2002-12-09 | S1 | 1544h | 1544h | IMSM-TR | Rel-6 | TSG |  | Juha Kalliokulju (Nokia) | juha.kalliokulju@nokia.com |  |  |
| 101 | 13.5.2 | Stage 1 22.340 | 23d? | 2002-11-11 A | 2002-12-11 A | 100% |  | 2002-11-11 | 2002-12-11 | 23d? |  | finish no earlier than 2002-12-11 | S1 | 184h | 184h | IMSM-TS | Rel-6 | TSG |  | Juha Kalliokulju (Nokia) | juha.kalliokulju@nokia.com |  |  |
| 102 | 13.5.3 | CRs to 22.140 & 22.228 | 263d? | 2002-03-14 A | 2003-03-17 A | 100% |  | 2002-03-14 | 2003-03-17 | 263d? |  | finish no earlier than 2003-03-17 | S1 | 2104h | 2104h | IMSM-CR | Rel-6 | TSG |  | Juha Kalliokulju (Nokia) | juha.kalliokulju@nokia.com |  |  |
| 103 | 16.11.3 | Stage 2 | 477d | 2002-11-04 A | 2004-08-31 | 82% | 85.86d | 2002-11-04 | 2003-09-26 | 235d | 205d | finish no earlier than 2004-08-31 | S2 | 3816h | 3129.12h |  | Rel-6 |  |  |  |  |  |  |
| 104 | 13.5.5 | Stage 3 for IMS Messaging | 454d? | 2002-12-13 A | 2004-09-08 | 50% | 227d? | 2002-12-13 | 2003-12-12 | 261d? | 199d | finish no earlier than 2004-09-08 | N1 | 3632h | 1816h |  |  |  |  | Keith Drage, Lucent | drage@lucent.com |  |  |
| 105 | 13.5.6 | SIP/SIMPLE Instant messaging | 130d? | 2004-01-01 | 2004-06-30 |  |  |  |  |  | 249d | finish no earlier than 2004-06-30 | OMA | 1040h |  |  | Rel-6 | n/a |  |  | OMA-LIAISON@mail.openmobilealliance.org |  |  |

Notes:
- 78: This is a building block without particular end date
- 82: Added BB UE authentication and rapporteur added.
- 83: Added by P-000575 without any dates. 18/10/00: Change of WI title, added hyperlink rapporteur new end date 03/01. New end date and correct Release to be decided S3#18
- 84: New end date and correct Release to be decided S3#18
- 85: WID approved for Rel-6 at SA#17
- 86: Should be complete after SA3#27 / Text3: TS 33.210
- 87: WID approved SA#19. Work started after FS approved SA#18
- 88: Approved TSG#21 / Text3: 42.068, 43.068, 44.068, 42.069, 43.069, 44.069, 31.102, 24.008, 48.008, 42.009, 43.020
- 89: Not yet available: verbally approved at SA15, actual WID to be provided at SA16 by Lucent
- 91: 29/05/2003 CN4: New WID presented for approval at CN#20............
- 101: Text3: 22.340
- 102: Text3: 22.140,22.228
- 105: Updated according to SP-040232

| ID | WBS | Task | Duration | Start | Finish | Complete | Remaining | Baseline start | Baseline finish | Baseline duration | Total slack | Constraint | Resources | Work | Actual work | Text3 | Text6 | Text4 | Text5 | Text1 | Text2 | Text7 | Text9 | Text8 |
| --- | --- | --- | --- | --- | --- | --- | --- | --- | --- | --- | --- | --- | --- | --- | --- | --- | --- | --- | --- | --- | --- | --- | --- | --- |
| 106 | 16.7 | **IMS Local services** | 895d? | 2001-01-01 A | 2004-06-04 | 46% | 485.89d? | 2001-01-01 | 2003-12-12 | 770d? | 267d |  | S2 | 12848h | 5192.02h | 23.228 | Rel-6 |  |  |  |  |  |  |  |
| 107 | 16.7.1 | Stage 2 | 325d | 2001-01-01 A | 2002-03-29 A | 100% |  | 2001-01-01 | 2002-03-29 | 325d |  | start no earlier than 2001-01-01 | S2 | 2600h | 2600h |  | Rel-6 |  |  |  |  |  |  |  |
| 108 | 13.6.2 | Stage 3 for IMS Local services | 386d? | 2002-12-13 | 2004-06-04 |  |  | 2002-12-13 | 2003-12-12 | 261d? | 267d | finish no earlier than 2004-06-04 | N1 | 3088h |  |  |  | Keith Drage, Lucent | drage@lucent.com |  |  |  |  |  |
| 109 | 13.7 | **Additional SIP Capabilities support not covered by Rel-5** | 478d? | 2002-11-11 A | 2004-09-08 | 77% | 110.02d? | 2002-11-11 | 2003-12-12 | 285d? | 199d |  | N1 | 10136h | 7803.05h |  | Rel-6 |  |  |  |  |  |  |  |
| 110 | 13.7.1 | Stage 2 for add SIP cap (e.g. forking) | 335d? | 2002-11-11 A | 2004-02-20 A | 100% |  | 2002-11-11 | 2003-06-27 | 165d? |  | finish no earlier than 2004-02-20 | S2 | 2680h | 2680h |  | Rel-6 |  |  |  |  |  |  |  |
| 111 | 13.7.2 | Stage 3 for Additional SIP Capabilities | 454d? | 2002-12-13 A | 2004-09-08 | 60% | 181.6d? | 2002-12-13 | 2003-12-12 | 261d? | 199d | finish no earlier than 2004-09-08 | N1 | 3632h | 2179.2h |  |  | Keith Drage, Lucent | drage@lucent.com |  |  |  |  |  |
| 112 | 13.8 | Review additional SIP Capabilities against IMS | 326d? | 2002-12-13 A | 2004-03-12 | 35% | 211.9d? | 2002-12-13 | 2003-12-12 | 261d? | 327d | finish no earlier than 2004-03-12 | N1 | 2608h | 912.8h |  |  | Keith Drage, Lucent | drage@lucent.com |  |  |  |  |  |
| 113 | 16.5 | **Interworking between IMS and IP networks** | 1055d? | 2000-08-28 A | 2004-09-10 | 60% | 420.73d? | 2000-08-28 | 2003-12-12 | 860d | 197d |  | N3 | 30704h | 15505.2h | 23.821, 29.061, 29.162 | Rel-6 | Nigel Holland, BT | nigel.holland@bt.com | IMS-CCR-IWIP | BaAS | TSG | 2048 |  |
| 114 | 16.5.1 | Interworking for 3GPP_SIP and IETF_SIP | 730d | 2000-08-28 A | 2003-06-13 A | 100% |  | 2000-08-28 | 2003-12-12 | 860d |  | finish no earlier than 2003-06-13 | N3 | 5840h | 5840h | New TR 29.962 | Rel-6 | Thomas Belling, Siemens |  |  |  |  |  |  |
| 115 | 16.5.2 | Interworking for IPv6 to IPv4 | 1055d | 2000-08-28 A | 2004-09-10 | 16% | 886.2d | 2000-08-28 | 2003-12-12 | 860d | 197d | finish no earlier than 2004-09-10 | N3 | 8440h | 1350.4h | 29.163 | Rel-6 |  |  |  |  |  |  |  |
| 116 | 13.9.3 | Interworking for IPv6 to IPv4 (SIP / SDP aspects) | 87d? | 2004-05-11 | 2004-09-08 |  |  |  |  |  | 199d | finish no earlier than 2004-09-08 | N1 | 696h |  |  | Rel-6 |  |  |  |  |  |  |  |
| 117 | 16.8.1 | stage 3 of interworking with non-IMS IP networks | 911d | 2001-03-14 A | 2004-09-08 | 85% | 136.65d | 2001-03-14 | 2003-12-12 | 718d | 199d | finish no earlier than 2004-09-08 | N1 | 7288h | 6194.8h |  | Rel-6 |  |  |  |  |  |  |  |
| 118 | 16.6.1 | Interworking between IMS and CS networks | 929d? | 2000-08-28 A | 2004-03-18 A | 100% |  | 2000-08-28 | 2003-09-05 | 790d? |  | finish no earlier than 2004-03-18 | N3 | 7432h | 7432h | 29.163, 29.061, 24.228, and new CN4 specification | Rel-6 | Brendan Mc Williams, Vodafone | brendan.mcwilliams@vf.vodafone.co.uk | IMS-CCR-IWCS | CCaR | TSG |  |  |
| 119 | 16.10 | Mn interface (IM-MGW to MGCF) enhancements (CN4 Part) | 418d | 2001-08-07 A | 2004-09-01 | 70% | 125.4d | 2002-09-02 | 2003-12-12 | 335d | 204d | finish no earlier than 2004-09-01 | N4 | 3344h | 2340.8h |  | Rel-6 |  |  | IMS-CCR-Mn |  |  |  |  |
| 120 | 13.12 | Mp (MRFC - MRFP) interface (CN4 Part) | 513d | 2002-12-13 | 2004-11-30 |  |  | 2002-10-07 | 2003-12-12 | 310d | 140d | finish no earlier than 2004-11-30 | N4 | 4104h |  |  | Rel-6 |  |  | IMS-CCR-Mp |  |  |  |  |
| 121 | 13.13 | Study of subscriber and operators relationship in IMS and related ISIM requirements for Rel 6” | 20d? | 2002-11-15 A | 2002-12-12 A | 100% |  | 2002-11-15 | 2002-12-12 | 20d? |  | finish no earlier than 2002-12-12 | S1 | 160h | 160h |  | Rel-6 | Juha Kalliokulju (Nokia) | juha.kalliokulju@nokia.com |  |  |  |  |  |
| 122 | 13.14 | Lawful Interception in the 3GPP Rel-6 architecture | 269d? | 2002-12-09 A | 2003-12-18 | 10% | 242.1d? | 2002-12-09 | 2003-12-18 | 269d? | 388d | finish no earlier than 2003-12-18 | S3 | 2152h | 215.2h | 33.106, 33.107, 33.108 | Rel-6 | Berthold Wilhelm | Berthold.Wilhelm@REGTP.DE | SEC1-LI |  | TSG |  |  |
| 123 | 13.15 | IMS Subscription and access scenarios | 130d? | 2002-12-16 A | 2003-06-13 A | 100% |  | 2002-12-16 | 2003-06-13 | 130d? |  | start no earlier than 2002-12-16 | S1 | 1040h | 1040h | 22.800 | Rel-6 |  |  |  |  |  |  |  |
| 124 | 14 | **3GPP Enablers for services like Push to Talk over Cellular (PoC)** | 344d? | 2003-09-08 A | 2004-12-30 | 29% | 243.3d? |  |  |  | 118d |  | S2 | 7416h | 2170.87h | 23.9xx | R6/R7? | Shabnam Sultana, Ericsson |  | PoC |  | TSG |  |  |
| 125 | 14.1 | Feasibility Study | 322d? | 2003-09-08 A | 2004-11-30 | 53% | 151.34d? |  |  |  | 140d | finish no earlier than 2004-11-30 | S2 | 2576h | 1365.28h | 23.9xx | R6/R7? | Shabnam Sultana, Ericsson |  | PoC |  |  |  |  |
| 126 | 14.2 | Dependencies on OMA PoC | 261d? | 2004-01-01 | 2004-12-30 |  |  |  |  |  | 118d | finish no earlier than 2004-12-30 | OMA | 2088h |  |  | R6/R7? |  | OMA-LIAISON@mail.openmobilealliance.org | PoC |  | n/a |  |  |
| 127 | 15 | Interworking aspects and migration scenarios for IPv4 based IMS Implementations (Study) | 210d? | 2003-09-08 A | 2004-06-25 A | 100% |  |  |  |  |  | finish no earlier than 2004-06-25 | S2 | 1680h | 1680h |  | Rel-6 | Alexander Milinski, Siemens |  | IPv4IMS |  |  |  |  |
| 128 | 16.3 | **Interoperability and Commonality between IMS using different "IP-connectivity Networks"** | 325d? | 2002-09-16 A | 2003-12-12 | 99% | 0d? | 2002-09-16 | 2003-12-12 | 325d | 0d |  | S2 | 9176h | 6736h |  | Rel-6 |  |  | IMSCOOP |  | TSG |  | Sang-Ui |
| 129 | 16.3.1 | Stage 2 for Interoperability (no contributions assumed that no more will be done in 3GPP hence work may need to be done in pp2) | 272d | 2002-09-16 A | 2003-09-30 A | 100% |  | 2002-09-16 | 2003-09-19 | 265d |  | finish no earlier than 2003-09-30 | S2 | 2176h | 2176h |  | Rel-6 | Balazs Beternyi, Nokia |  |  |  |  |  |  |
| 130 | 16.2 | Stage 2 for commonality | 265d? | 2002-09-16 A | 2003-09-19 A | 100% |  | 2002-09-16 | 2003-09-19 | 265d? |  | start no earlier than 2002-09-16 | S2 | 2120h | 2120h |  | Rel-6 | Balazs Beternyi, Nokia |  |  |  |  |  |  |
| 131 | 16.3.2 | Stage 3 | 305d | 2002-10-14 A | 2003-12-12 A | 100% |  | 2002-10-14 | 2003-12-12 | 305d |  | finish no earlier than 2003-12-12 | N1 | 2440h | 2440h |  | Rel-6 | Keith Drage, Lucent | drage@lucent.com |  |  |  |  |  |

Notes:
- 113: [DAB 14.02.02] - end date pushed back to March 2003
- 114: [DAB - 20.08.03] - CN Part of TR Complete @ CN#20
- 115: [DAB - 25.05.04] - Awaiting Stage 2
- 118: [DAB - 25.05.04] - CN3 consider this work to be complete
- 119: [CN4] 17th May 2002, CN4; Will be handled in Rel-6.........
- 120: 27/11/2002 KK: WID approved at CN#18 (NP-020601)......
- 126: Updated according to SP-040232

| ID | WBS | Task | Duration | Start | Finish | Complete | Remaining | Baseline start | Baseline finish | Baseline duration | Total slack | Constraint | Resources | Work | Actual work | Text1 | Text2 | Text4 | Text6 | Text7 | Text8 | Text9 | Text5 | Text3 |
| --- | --- | --- | --- | --- | --- | --- | --- | --- | --- | --- | --- | --- | --- | --- | --- | --- | --- | --- | --- | --- | --- | --- | --- | --- |
| 132 | 17 | **Support of Push Services** | 823d | 2001-01-03 A | 2004-02-27 | 99% | 0d | 2001-01-03 | 2003-12-26 | 778d | 0d |  | S1 | 11390.6h | 5744h | PUSH | CCaR | Yoshinori Kitada, NTT Comware | Rel-6 | TSG | Sang-Ui | 1365 |  |  |
| 133 | 17.1 | Stage 1 | 378d | 2001-01-03 A | 2002-06-14 A | 100% |  | 2001-01-03 | 2002-06-14 | 378d |  | finish no earlier than 2002-06-14 | S1 | 3024h | 3024h |  |  |  | Rel-6 |  |  |  |  |  |
| 134 | 17.3 | TR 23.976 on Push Architecture | 340d | 2002-11-11 A | 2004-02-27 A | 100% |  | 2002-11-11 | 2003-12-26 | 295d |  | finish no earlier than 2004-02-27 | S2 | 2720h | 2720h |  |  | Nick Alfano, RIM | Rel-6 |  |  |  |  |  |
| 135 | 18 | **Multimedia Messaging (MMS) enhancements** | 546d? | 2002-08-15 A | 2004-09-16 | 55% | 244.74d? | 2002-08-15 | 2004-03-10 | 410d? | 193d |  | T2 | 21398.8h | 12832.5h | MMS6 | Mes | Josef Laumen, Siemens | Rel-6 | TSG | Friedhelm |  | Josef.Laumen@SAL.SIEMENS.DE |  |
| 136 | 18.1 | **Definition of service requirements** | 286d? | 2002-11-15 A | 2003-12-19 A | 100% |  | 2002-11-15 | 2003-12-20 | 286d? |  |  | S1 | 4576h | 4576h | MMS6-SR |  |  | Rel-6 |  |  |  |  | 22.140 |
| 137 | 18.1.1 | Definition of service requirements charging | 286d? | 2002-11-15 A | 2003-12-19 A | 100% |  | 2002-11-15 | 2003-12-20 | 286d? |  | finish no earlier than 2003-12-20 | S1 | 2288h | 2288h |  |  | Josef Laumen, Siemens | Rel-6 |  |  |  | Josef.Laumen@SAL.SIEMENS.DE | 22.140 |
| 138 | 18.2 | Technical realization | 526d | 2002-09-06 A | 2004-09-10 | 55% | 236.7d | 2002-08-15 | 2003-12-10 | 345d | 197d | finish no earlier than 2004-09-10 | T2 | 4208h | 2314.4h |  |  | Josef Laumen, Siemens | Rel-6 | TSG | Friedhelm |  | Josef.Laumen@SAL.SIEMENS.DE | 23.140 |
| 139 | 18.3 | OMA dependencies on MMS (MM1 interface and terminal provisionning) | 228.85d | 2003-08-15 A | 2004-08-27 |  | 228.85d | 2002-08-15 | 2004-03-10 | 410d | 207d | finish no earlier than 2004-08-27 | OMA | 1830.8h |  |  |  |  | Rel-6 | n/a | Friedhelm |  | OMA-LIAISON@mail.openmobilealliance.org |  |
| 140 | 18.4 | MMS formats and codecs | 546d | 2002-08-15 A | 2004-09-16 | 75% | 136.5d | 2002-08-15 | 2003-12-18 | 351d | 193d | finish no earlier than 2004-09-16 | S4 | 4368h | 3276h | MMS6-Codec |  | Roberto Castagno (Nokia) | Rel-6 |  | Paolo |  | roberto.castagno@nokia.com | 26.140 |
| 141 | 18.5 | Handling of private addressing schemes in MMS | 128d | 2003-12-10 A | 2004-06-04 | 20% | 102.4d |  |  |  | 267d | start no earlier than 2003-12-10 | T2 | 1024h | 204.8h |  |  | Matthias Röbke, T-Mobile | Rel-6 | TSG | Friedhelm |  | Matthias.Roebke@t-mobile.de | 23.140 |
| 142 | 18.6 | FS Multiple MMS Relay/Server Architecture | 128d | 2003-12-10 A | 2004-06-04 | 5% | 121.6d |  |  |  | 267d | start no earlier than 2003-12-10 | T2 | 1024h | 51.2h |  |  | Juan Gorospe, Telefónica Móviles | Rel-6 | TSG | Friedhelm |  | gorospe_j@tsm.es | new TR |
| 143 | 19 | **Rel-6 MExE enhancements** | 326d | 2002-03-08 A | 2003-06-06 A | 100% |  | 2002-03-08 | 2003-06-06 | 326d |  |  | T2 | 7328h | 7328h | MEXE6 | Ter |  | Rel-6 | TSG | Friedhelm |  |  |  |
| 144 | 19.1 | MExE Rel-6 Improvements and Investigations | 264d | 2002-03-08 A | 2003-03-12 A | 100% |  | 2002-03-08 | 2003-03-12 | 264d |  | finish no earlier than 2003-03-12 | T2 | 2112h | 2112h | MEXE6-ENHANC | Ter | Lars Brenk (TTPCom) | Rel-6 | TSG |  |  | lsb_ttpcom@HOTMAIL.COM | 22.057, 23.057 |
| 145 | 19.2 | MExE Run-Time Independent Framework Feasibility Study | 326d | 2002-03-08 A | 2003-06-06 A | 100% |  | 2002-03-08 | 2003-06-06 | 326d |  | finish no earlier than 2003-06-06 | T2 | 2608h | 2608h | MEXE6-RTIF | Ter | Aaron Cohen (Intel) | Rel-6 | TSG |  |  | Aaron.Cohen@intel.com | 22.857 |
| 146 | 21 | Subscription Management | 520d | 2002-09-20 A | 2004-09-16 | 75% | 130d | 2000-12-29 | 2004-03-19 | 841d | 193d | finish no earlier than 2004-09-16 | S5 | 4160h | 3120h | SuM |  | Istvan ABA (T-Mobile Austria) | Rel-6 | TSG | Adrian |  | istvan.aba@t-mobile.at | 32.140/1, 32.171/2 |
| 147 | 22 | **Presence Capability** | 990d? | 2001-03-19 A | 2004-12-31 | 49% | 503.87d? | 2001-03-19 | 2003-12-19 | 720d? | 117d |  | S1 | 32376h | 15897.8h | PRESNC |  | Mark Cataldo, Motorola | Rel-6 | TSG | Michael | 11004 |  |  |
| 148 | 22.1 | Stage 1 | 610d | 2001-03-19 A | 2003-07-18 A | 100% |  | 2001-03-19 | 2003-07-18 | 610d |  | finish no earlier than 2003-07-18 | S1 | 4880h | 4880h |  |  |  | Rel-6 |  |  | 11005 |  |  |
| 149 | 22.2 | Stage 2 | 268d | 2001-09-12 A | 2002-09-20 A | 100% |  | 2001-09-12 | 2002-09-20 | 268d |  | finish no earlier than 2002-09-20 | S2 | 2144h | 2144h |  |  |  | Rel-6 | TSG |  |  |  |  |
| 150 | 22.3 | Stage 3 | 638d | 2002-04-01 A | 2004-09-08 | 90% | 63.8d | 2002-04-01 | 2003-12-19 | 450d | 199d | finish no earlier than 2004-09-08 | N1 | 5104h | 4593.6h |  |  | Keith Drage, Lucent | Rel-6 |  |  |  | drage@lucent.com |  |
| 151 | 21.4 | Stage 3 (CN3 Part Pk interface) | 638d? | 2002-04-01 | 2004-09-08 |  |  |  |  |  | 199d | start no earlier than 2002-04-01 | N3 | 5104h |  |  |  |  | Rel-6 |  |  |  |  |  |
| 152 | 21.5 | Media Codecs and Formats for IMS Messaging and Presence | 331d? | 2003-06-12 A | 2004-09-16 | 10% | 297.9d? | 2003-06-12 | 2003-12-18 | 136d? | 193d | finish no earlier than 2004-09-16 | S4 | 2648h | 264.8h | PRESNC-COFIMP |  | Harri Honko (Nokia) | Rel-6 | TSG | Paolo |  | harri.honko@nokia.com | TS 26.141 |
| 153 | 22.4 | Security issues | 79d | 2002-08-26 A | 2002-12-12 | 20% | 63.2d | 2002-08-26 | 2002-12-12 | 79d | 653d | finish no earlier than 2002-12-12 | S3 | 632h | 126.4h |  |  |  | Rel-6 |  |  |  |  |  |
| 154 | 22.5 | USIM issues | 79d | 2002-03-04 | 2002-06-20 |  |  | 2002-03-04 | 2002-06-20 | 79d | 778d | start no earlier than 2002-03-04 | T3 | 632h |  |  |  |  | Rel-6 |  |  |  |  |  |
| 155 | 21.8 | TR on Presence and Availability Management | 175d | 2004-05-03 | 2004-12-31 |  |  |  |  |  | 117d | start no earlier than 2004-05-01 | N5 | 1400h |  |  |  |  | Rel-6 | TSG |  |  |  | 29.998-14 |
| 156 | 21.9 | SIMPLE Presence | 239d? | 2004-01-01 | 2004-11-30 |  |  |  |  |  | 140d | finish no earlier than 2004-11-30 | OMA | 1912h |  |  |  |  | Rel-6 | n/a |  |  | OMA-LIAISON@mail.openmobilealliance.org |  |

Notes:
- 132: AS: Changed from FS to actual support of Push
- 139: Updated according to SP-040232
- 147: A Sultan merged "Presence Service Enhancements" (UID31028, PRES1) to this feature as no answer was provided on why Presence and Presence Encmts had same target completion date
- 151: No Contributions so far
- 152: Also for 31022 IMS Messaging
- 153: LSs handled in SA3. WID approved SA#17 Contribution at S3#25 & following e-mail discussion.
- 155: CN#23: Moved from OSA3 to PRESNC
- 156: Updated according to SP-040232

| ID | WBS | Task | Duration | Start | Finish | Complete | Remaining | Baseline start | Baseline finish | Baseline duration | Total slack | Constraint | Resources | Work | Actual work | Text1 | Text4 | Text5 | Text6 | Text7 | Text8 |
| --- | --- | --- | --- | --- | --- | --- | --- | --- | --- | --- | --- | --- | --- | --- | --- | --- | --- | --- | --- | --- | --- |
| 157 | 25 | **Enhanced A/Gb feasibility study** | 51d? | 2002-08-30 A | 2002-11-08 | 75% | 12.75d? | 2002-08-30 | 2002-11-08 | 51d? | 677d |  | GP | 4080h | 3162h | AGbEnFS | J-L Carrizo, Vodafone | jose-luis.carrizo@vodafone.co.uk | Rel-6 | TSG | Paolo |
| 158 | 25.1 | **Feasibility study on A/Gb enhancements** | 51d? | 2002-08-30 A | 2002-11-08 | 75% | 12.75d? | 2002-08-30 | 2002-11-08 | 51d? | 677d |  | G2 | 3672h | 2856h | AGbEnFS-FS |  |  | Rel-6 | TSG |  |
| 159 | 25.1.1 | Requirements for the support of conversational services | 51d | 2002-08-30 A | 2002-11-08 A | 100% |  | 2002-08-30 | 2002-11-08 | 51d |  | finish no earlier than 2002-11-08 | GP | 408h | 408h |  |  |  | Rel-6 |  |  |
| 160 | 22.1.2 | Identification of the different building blocks for the provision of conversational services on the existing A/Gb protocol stack | 51d? | 2002-08-30 A | 2002-11-08 A | 100% |  | 2002-08-30 | 2002-11-08 | 51d? |  | finish no earlier than 2002-11-08 | GP | 408h | 408h |  |  |  | Rel-6 |  |  |
| 161 | 22.1.3 | Outline of impact and feasibility of these building blocks and their different solutions | 51d? | 2002-08-30 A | 2002-11-08 A | 100% |  | 2002-08-30 | 2002-11-08 | 51d? |  | finish no earlier than 2002-11-08 | GP | 408h | 408h |  |  |  | Rel-6 |  |  |
| 162 | 25.1.2 | Identification of the different building blocks for the provision of conversational services on the existing A/Gb protocol stack | 51d | 2002-08-30 | 2002-11-08 |  |  | 2002-08-30 | 2002-11-08 | 51d | 677d | finish no earlier than 2002-11-08 | G2 | 408h |  |  |  |  | Rel-6 |  |  |
| 163 | 25.1.3 | Outline of impact and feasibility of these building blocks and their different solutions | 51d | 2002-08-30 | 2002-11-08 |  |  | 2002-08-30 | 2002-11-08 | 51d | 677d | finish no earlier than 2002-11-08 | G2 | 408h |  |  |  |  | Rel-6 |  |  |
| 164 | 25.1.4 | Impact on 3GPP architecture and requirement to co-ordinatge with other TSGs (CN, SA) | 51d | 2002-08-30 A | 2002-11-08 A | 100% |  | 2002-08-30 | 2002-11-08 | 51d |  | finish no earlier than 2002-11-08 | GP | 408h | 408h |  |  |  | Rel-6 |  |  |
| 165 | 25.1.5 | Standardisation effort | 51d | 2002-08-30 A | 2002-11-08 A | 100% |  | 2002-08-30 | 2002-11-08 | 51d |  | finish no earlier than 2002-11-08 | GP | 408h | 408h |  |  |  | Rel-6 |  |  |
| 166 | 25.1.6 | Dependency to other features | 51d | 2002-08-30 A | 2002-11-08 A | 100% |  | 2002-08-30 | 2002-11-08 | 51d |  | finish no earlier than 2002-11-08 | GP | 408h | 408h |  |  |  | Rel-6 |  |  |
| 167 | 26 | **Flexible Layer One for GERAN** | 1170d | 2000-01-03 A | 2004-06-25 | 96% | 51.16d | 2000-01-03 | 2003-11-21 | 1015d | 252d |  | GP | 76383h | 54490.9h | FLOGER | Benoist Sébire | benoist.sebire@nokia.com | Rel-6 | TSG | Paolo |
| 168 | 26.1 | **Realisation of a Flexible Layer One** | 1125d | 2000-01-03 A | 2004-04-23 | 99% | 0d | 2000-01-03 | 2003-06-27 | 910d | 0d |  | GP | 42808h | 36720h | FLOGER-Real | Benoist Sébire | benoist.sebire@nokia.com | Rel-6 |  |  |
| 169 | 26.1.1 | Technical Report | 471d | 2002-04-19 A | 2004-02-06 A | 100% |  | 2002-04-19 | 2003-06-27 | 311d |  | finish no earlier than 2004-02-06 | GP | 3768h | 3768h |  |  |  | Rel-6 |  |  |
| 170 | 26.1.2 | Architecture in 45.001 and 43.051 | 526d | 2002-04-19 A | 2004-04-23 A | 100% |  | 2002-04-19 | 2003-06-27 | 311d |  | finish no earlier than 2004-04-23 | G1 | 4208h | 4208h |  |  |  | Rel-6 |  |  |
| 171 | 26.1.3 | Multiplexing in 45.002 | 526d | 2002-04-19 A | 2004-04-23 A | 100% |  | 2002-04-19 | 2003-06-27 | 311d |  | finish no earlier than 2004-04-23 | G1 | 4208h | 4208h |  |  |  | Rel-6 |  |  |
| 172 | 26.1.4 | Channel Coding in 45.003 | 526d | 2002-04-19 A | 2004-04-23 A | 100% |  | 2002-04-19 | 2003-06-27 | 311d |  | finish no earlier than 2004-04-23 | G1 | 4208h | 4208h |  |  |  | Rel-6 |  |  |
| 173 | 26.1.5 | Performance Requirements in 45.005 | 1125d | 2000-01-03 A | 2004-04-23 A | 100% |  | 2000-01-03 | 2003-06-27 | 910d |  | finish no earlier than 2004-04-23 | G1 | 9000h | 9000h |  |  |  | Rel-6 |  |  |
| 174 | 26.1.6 | Radio subsystem link control in 45.008 | 526d | 2002-04-19 A | 2004-04-23 A | 100% |  | 2002-04-19 | 2003-06-27 | 311d |  | finish no earlier than 2004-04-23 | G1 | 4208h | 4208h |  |  |  | Rel-6 |  |  |
| 175 | 26.1.7 | Requirements in 44.004 | 526d | 2002-04-19 A | 2004-04-23 A | 100% |  | 2002-04-19 | 2003-06-27 | 311d |  | finish no earlier than 2004-04-23 | G2 | 4208h | 4208h |  |  |  | Rel-6 |  |  |
| 176 | 26.2 | **Signalling and protocol support for a Flexible Layer One** | 571d | 2002-04-19 A | 2004-06-25 | 95% | 28.55d | 2002-04-19 | 2003-06-27 | 311d | 252d |  | G2 | 13704h | 9677.6h | FLOGER-SigPro | Benoist Sébire | benoist.sebire@nokia.com | Rel-6 |  |  |
| 177 | 26.2.1 | Modifications to RLC/MAC in 44.060 and 44.160 | 571d | 2002-04-19 A | 2004-06-25 | 95% | 28.55d | 2002-04-19 | 2003-06-27 | 311d | 252d | finish no earlier than 2004-06-25 | G2 | 4568h | 4339.6h |  |  |  | Rel-6 |  |  |
| 178 | 26.2.2 | Modifications to RRC in 44.118 and 44.018 | 571d | 2002-04-19 A | 2004-06-25 | 95% | 28.55d | 2002-04-19 | 2003-06-27 | 311d | 252d | finish no earlier than 2004-06-25 | G2 | 4568h | 4339.6h |  |  |  | Rel-6 |  |  |
| 179 | 26.3 | **Security for a Flexible Layer One** | 356d | 2002-04-19 A | 2003-08-29 A | 100% |  | 2002-04-19 | 2003-06-27 | 311d |  |  | S3, G2 | 5663.04h | 5663.04h | FLOGER-SecFLO | Benoist Sébire | benoist.sebire@nokia.com | Rel-6 |  |  |
| 180 | 26.3.1 | Ciphering in 44.160,44.118, 44.060 and 44.018 | 356d | 2002-04-19 A | 2003-08-29 A | 100% |  | 2002-04-19 | 2003-06-27 | 311d |  | finish no earlier than 2003-08-29 | S3, G2 | 2848h | 2848h |  |  |  | Rel-6 |  |  |

Notes:
- 157: Closed
- 167: Nokia, Ericsson, Siemens, Telia
- 168: Started
- 176: Started
- 179: Started

| ID | WBS | Task | Duration | Start | Finish | Complete | Remaining | Baseline start | Baseline finish | Baseline duration | Total slack | Constraint | Resources | Work | Actual work | Text1 | Text4 | Text5 | Text6 | Text3 | Text8 | Text7 | Text9 |
| --- | --- | --- | --- | --- | --- | --- | --- | --- | --- | --- | --- | --- | --- | --- | --- | --- | --- | --- | --- | --- | --- | --- | --- |
| 181 | 26.4 | **GERAN MS Conformance test for the Flexible Layer One** | 101d | 2004-02-06 | 2004-06-25 |  |  | 2002-11-22 | 2003-11-21 | 260.5d | 252d |  | G4; G5 | 3232h |  | FLOGER-Msconf | Benoist Sébire | benoist.sebire@nokia.com | Rel-6 |  |  |  |  |
| 182 | 26.4.1 | MS Test in 51.01050085 | 101d | 2004-02-06 | 2004-06-25 |  |  | 2002-11-22 | 2003-11-21 | 260.5d | 252d | start no earlier than 2004-02-06 | G4; G5 | 1616h |  |  |  |  | Rel-6 |  |  |  |  |
| 183 | 26.5 | **GERAN BTS Conformance test for the Flexible Layer One** | 101d | 2004-02-06 | 2004-06-25 |  |  | 2002-04-19 | 2003-11-21 | 416d | 252d |  | G3 | 1616h |  | FLOGER-BTSconf | Benoist Sébire | benoist.sebire@nokia.com | Rel-6 |  |  |  |  |
| 184 | 26.5.1 | BTS Test in 51.021 | 101d | 2004-02-06 | 2004-06-25 |  |  | 2002-04-19 | 2003-11-21 | 416d | 252d | start no earlier than 2004-02-06 | G3 | 808h |  |  |  |  | Rel-6 |  |  |  |  |
| 185 | 27 | Uplink TDOA feasibility study | 151d | 2001-11-30 A | 2002-06-28 A | 100% |  | 2001-11-30 | 2002-06-28 | 151d |  | finish no earlier than 2002-06-28 | GP | 1208h | 1208h | TDOAF | Bob Gross, TruePosition, Inc. | rlgross@trueposition.com | Rel-6 | 45.811 | Paolo |  |  |
| 186 | 28 | **Multimedia Broadcast and Multicast Service** | 940d? | 2001-05-11 A | 2004-12-16 | 43% | 537.17d? | 2001-05-11 | 2004-03-19 | 746d | 128d |  | S1 | 108762h | 41678.1h | MBMS |  |  | Rel-6 |  | Michael | TSG |  |
| 187 | 28.1 | Stage 1 | 232d | 2001-05-11 A | 2002-04-01 A | 100% |  | 2001-05-11 | 2002-04-01 | 232d |  | finish no earlier than 2002-04-01 | S1 | 1856h | 1856h |  |  |  | Rel-6 | 22.146, 22.101 |  |  | 11003 |
| 188 | 28.2 | **Stage 2** | 648d | 2001-09-24 A | 2004-03-17 | 99% | 0d | 2001-09-24 | 2003-09-19 | 520d | 0d |  | S2 | 10408h | 6548.8h |  |  |  | Rel-6 |  |  | TSG |  |
| 189 | 28.2.1 | TR on Architectural Study | 240d | 2001-09-24 A | 2002-08-23 A | 100% |  | 2001-09-24 | 2002-08-23 | 240d |  | finish no earlier than 2002-08-23 | S2 | 1920h | 1920h |  |  |  | Rel-6 |  |  |  |  |
| 190 | 28.2.2 | Stage 2 Specification Work. (User Service aspects may impact) (progress will be check in Friday of S2 #38 !!) | 413d | 2002-08-19 A | 2004-03-17 A | 100% |  | 2002-08-19 | 2003-09-19 | 285d |  | finish no earlier than 2004-03-17 | S2 | 3304h | 3304h |  |  |  | Rel-6 |  |  |  |  |
| 191 | 28.3 | Introduction of MBMS in RAN | 707d | 2002-01-01 A | 2004-09-15 | 80% | 141.4d | 2002-01-01 | 2004-03-19 | 579d | 194d | finish no earlier than 2004-09-15 | R2 | 5656h | 4524.8h | MBMS-RAN | Juho Pirskanen , Nokia | juho.pirskanen@nokia.com | Rel-6 |  | MCC_RAN | TSG | 2481 |
| 192 | 28.4 | Support of the MBMS in CN protocols | 582d | 2002-06-18 A | 2004-09-08 | 78% | 128.04d | 2002-06-18 | 2003-12-12 | 389d | 199d | finish no earlier than 2004-09-08 | N1 | 4656h | 3631.68h |  |  |  | Rel-6 |  |  | TSG |  |
| 193 | 25.5 | Gmb interface for MBMS (CN3 part) | 271d | 2003-08-29 A | 2004-09-10 | 50% | 135.5d |  |  |  | 197d | finish no earlier than 2004-09-10 | N3 | 2168h | 1084h |  |  |  | Rel-6 | 29.061 |  |  |  |
| 194 | 28.5 | Security Aspects of Multimedia Broadcast/Multicast Service (MBMS) | 324d | 2002-07-01 A | 2003-09-25 | 20% | 259.2d | 2002-07-01 | 2003-02-28 | 175d | 448d | finish no earlier than 2003-09-25 | S3 | 2592h | 518.4h | MBMS | Escott, Adrian, 3 | adrian.escott@three.co.uk | Rel-6 |  |  | TSG |  |
| 195 | 28.6 | **Support of MBMS in GERAN** | 837d? | 2001-08-30 A | 2004-11-12 | 29% | 596.44d? | 2002-08-30 | 2003-11-21 | 321d | 152d |  | GP | 65808h | 17775.1h | MBMS-GERAN |  |  | Rel-6 |  |  | TSG |  |
| 196 | 28.6.1 | Impact on the logical and physical channels | 576d | 2002-08-30 A | 2004-11-12 | 35% | 374.4d | 2002-08-30 | 2003-11-21 | 321d | 152d | finish no earlier than 2004-11-12 | GP | 4608h | 1612.8h |  |  |  | Rel-6 |  |  |  |  |
| 197 | 28.6.4 | Re-synchronisation at cell change | 576d | 2002-08-30 | 2004-11-12 |  |  | 2002-08-30 | 2003-06-27 | 216d | 152d | finish no earlier than 2004-11-12 | G2 | 4608h |  |  |  |  | Rel-6 |  |  |  |  |
| 198 | 25.7.3 | Simultaneous support of MBMS services | 576d? | 2002-08-30 A | 2004-11-12 | 35% | 374.4d? |  |  |  | 152d | finish no earlier than 2004-11-12 | GP | 4608h | 1612.8h |  |  |  | Rel-6 |  |  |  |  |
| 199 | 25.7.4 | Simultaneous support of MBMS and non-MBMS services | 837d? | 2001-08-30 A | 2004-11-12 | 35% | 544.05d? |  |  |  | 152d | finish no earlier than 2004-11-12 | GP | 6696h | 2343.6h |  |  |  | Rel-6 |  |  |  |  |
| 200 | 25.7.5 | Resynchronisation at cell change | 837d? | 2001-08-30 A | 2004-11-12 | 35% | 544.05d? |  |  |  | 152d | finish no earlier than 2004-11-12 | GP | 6696h | 2343.6h |  |  |  | Rel-6 |  |  |  |  |
| 201 | 28.6.5 | Decision making process between point-to-point or pont-to-multipoint configurations | 576d | 2002-08-30 A | 2004-11-12 | 35% | 374.4d | 2002-08-30 | 2003-11-21 | 321d | 152d | finish no earlier than 2004-11-12 | GP | 4608h | 1612.8h |  |  |  | Rel-6 |  |  |  |  |
| 202 | 28.6.6 | MBMS channel allocations procedures to multiple MSs | 576d | 2002-08-30 A | 2004-11-12 | 35% | 374.4d | 2002-08-30 | 2003-11-21 | 321d | 152d | finish no earlier than 2004-11-12 | GP | 4608h | 1612.8h |  |  |  | Rel-6 |  |  |  |  |
| 203 | 28.6.7 | Changes to the Gb interface | 576d | 2002-08-30 A | 2004-11-12 | 35% | 374.4d | 2002-08-30 | 2003-11-21 | 321d | 152d | finish no earlier than 2004-11-12 | GP | 4608h | 1612.8h |  |  |  | Rel-6 |  |  |  |  |
| 204 | 28.6.8 | GERAN specific changes to the Iu-ps interface | 576d | 2002-08-30 A | 2004-11-12 | 35% | 374.4d | 2002-08-30 | 2003-11-21 | 321d | 152d | finish no earlier than 2004-11-12 | GP | 4608h | 1612.8h |  |  |  | Rel-6 |  |  |  |  |
| 205 | 28.6.9 | Interaction between MBMS and Iu-flex | 576d | 2002-08-30 A | 2004-11-12 | 35% | 374.4d | 2002-08-30 | 2003-11-21 | 321d | 152d | finish no earlier than 2004-11-12 | GP | 4608h | 1612.8h |  |  |  | Rel-6 |  |  |  |  |
| 206 | 28.6.10 | Security aspects | 576d | 2002-08-30 A | 2004-11-12 | 35% | 374.4d | 2002-08-30 | 2003-11-21 | 321d | 152d | finish no earlier than 2004-11-12 | GP | 4608h | 1612.8h |  |  |  | Rel-6 |  |  |  |  |
| 207 | 25.7.12 | MS conformance tests- G3 | 576d? | 2002-08-30 | 2004-11-12 |  |  |  |  |  | 152d | finish no earlier than 2004-11-12 | G3 | 4608h |  |  |  |  | Rel-6 |  |  |  |  |
| 208 | 28.6.11 | DELETE - MS conformance tests - G5 | 216d | 2002-08-30 | 2003-06-27 |  |  | 2002-08-30 | 2003-06-27 | 216d | 512d | finish no earlier than 2003-06-27 | G5 | 1728h |  |  |  |  | Rel-6 |  |  |  |  |

Notes:
- 181: Not started
- 183: Not started
- 186: Title renamed at SA#13
- 187: This may or may not be a separate stage 1. In the meantime, CRs are proposed for 22.101
- 194: WID approved SA#17
- 208: DELETE !

| ID | WBS | Task | Duration | Start | Finish | Complete | Remaining | Baseline start | Baseline finish | Baseline duration | Total slack | Constraint | Resources | Work | Actual work | Text3 | Text6 | Text8 | Text9 | Text1 | Text4 | Text5 | Text7 |
| --- | --- | --- | --- | --- | --- | --- | --- | --- | --- | --- | --- | --- | --- | --- | --- | --- | --- | --- | --- | --- | --- | --- | --- |
| 209 | 28.1 | **MBMS User Services** | 418d? | 2003-05-13 A | 2004-12-16 | 69% | 131.58d? | 2001-05-11 | 2002-04-01 | 232d | 128d |  | S1 | 8376h | 5739.36h | 22.246 | Rel-6 | Michael | 11003 |  |  |  |  |
| 210 | 28.1 | MBMS User Services Stage 1 | 233d | 2003-05-13 A | 2004-04-01 A | 100% |  | 2001-05-11 | 2002-04-01 | 232d |  | start no earlier than 2003-05-13 | S1 | 1864h | 1864h | 22.246 | Rel-6 | Michael | 11003 |  |  |  |  |
| 211 | 25.8.2 | Definition of MBMS user services, media codecs, formats and transport/application protocols using MBMS | 396d? | 2003-06-12 A | 2004-12-16 | 50% | 198d? | 2003-06-12 | 2004-03-18 | 201d? | 128d | finish no earlier than 2004-12-16 | S4 | 3168h | 1584h | 26.346 | Rel-6 | Paolo |  | MBMS-TSMBMS | Igor Curcio (Nokia) | igor.curcio@nokia.com | TSG |
| 212 | 29 | **Speech Recognition and Speech Enabled Services** | 699d? | 2001-10-08 A | 2004-06-10 | 97% | 20.8d? | 2001-10-08 | 2003-12-09 | 567d? | 263d |  | S1 | 11680h | 11332.4h |  | Rel-6 | Michael |  | SRSES |  |  | TSG |
| 213 | 29.1 | Speech Enabled Services Based on Distributed Speech Recognition (DSR) | 115d | 2001-10-08 A | 2002-03-15 A | 100% |  | 2001-10-08 | 2002-03-15 | 115d |  | finish no earlier than 2002-03-15 | S1 | 920h | 920h | 22.941, 23.207, 22.243 | Rel-6 |  |  | DSR | D Williams, QUALCOMM, Inc. | Dwilliams@qualcomm.com | TSG |
| 214 | 29.2 | TR on Architectural impacts | 212d | 2003-05-12 A | 2004-03-02 A | 100% |  | 2003-05-12 | 2003-12-09 | 152d |  | finish no earlier than 2004-03-02 | S2 | 1696h | 1696h |  | Rel-6 |  |  |  |  |  |  |
| 215 | 26.3 | Codec Work to Support Speech Recognition Framework for Automated Voice Services | 433d? | 2002-10-15 A | 2004-06-10 | 95% | 21.65d? | 2002-10-15 | 2003-09-26 | 249d? | 263d | finish no earlier than 2004-06-10 | S4 | 3464h | 3290.8h | 26.235, 26.236, 26.243 | Rel-6 | Paolo |  | SRSES-Codec | David Pearce, Motorola | bdp003@motorola.com | WG |
| 216 | 26.4 | Multimodal support | 1d? | 2004-01-01 | 2004-01-01 |  |  |  |  |  | 378d | start no earlier than 2004-01-01 | OMA | 8h |  |  | Rel-6 |  |  |  |  | OMA-LIAISON@mail.openmobilealliance.org |  |
| 217 | 30 | **Generic User Profile** | 822d | 2001-10-08 A | 2004-11-30 | 68% | 259.15d | 2001-10-08 | 2003-12-12 | 570d | 140d |  | S1 | 24807.8h | 16986.7h |  | Rel-6 | Michael |  | GUP |  |  | TSG |
| 218 | 30.1 | Stage 1 - Requirements | 430d | 2001-10-08 A | 2003-05-30 A | 100% |  | 2001-10-08 | 2003-05-30 | 430d |  | finish no earlier than 2002-12-09 | S1 | 3440h | 3440h | 22.240, 22.228 | Rel-6 |  |  |  | Paul Amery (Orange) | paul.amery@orange.co.uk |  |
| 219 | 30.3 | Stage 2 - Architecture | 355d | 2002-01-28 A | 2003-06-06 A | 100% |  | 2002-01-28 | 2003-06-06 | 355d |  | finish no earlier than 2003-06-06 | S2 | 2840h | 2840h | 23.240 | Rel-6 |  |  |  | Nacho Uzquiano (Telefonica) | uzquiano_ji@tsm.es |  |
| 220 | 30.2 | Stage 2 - Data Description Method | 327d | 2002-12-05 A | 2004-03-05 | 90% | 32.7d | 2001-10-08 | 2003-12-10 | 568d | 332d | finish no earlier than 2004-03-05 | T2 | 2616h | 2354.4h | 23.241 | Rel-6 | Friedhelm |  |  | Kurt Bischinger (T-Mobile AUSTRIA) | kurt.bischinger@t-mobile.at | TSG |
| 221 | 30.4 | Stage 3 - Common objects | 457d | 2002-12-05 A | 2004-09-03 | 60% | 182.8d | 2001-10-08 | 2003-12-10 | 568d | 202d | finish no earlier than 2004-09-03 | T2 | 3656h | 2193.6h | 24.241 | Rel-6 | Friedhelm |  |  |  |  | TSG |
| 222 | 30.5 | Stage 3 - Network | 401.98d | 2003-05-19 A | 2004-11-30 | 40% | 241.19d | 2003-05-19 | 2003-12-12 | 149.98d | 140d | finish no earlier than 2004-11-30 | N4 | 3215.84h | 1286.34h | 29.240 | Rel-6 |  |  |  |  |  |  |
| 223 | 30.6 | Security Aspects | 308d | 2002-07-16 A | 2003-09-18 | 15% | 261.8d | 2002-07-16 | 2003-09-18 | 308d | 453d | finish no earlier than 2003-09-18 | S3 | 2464h | 369.6h | 33.102, 33.203, 33.210 | Rel-6 |  |  |  | Owen, Bradley | bvowen@lucent.com | WG |
| 224 | 31 | **Digital Rights Management** | 690d? | 2001-10-08 A | 2004-05-28 | 39% | 422.65d? | 2001-10-08 | 2003-03-21 | 380d? | 272d |  | S1 | 11392h | 4414.01h |  | Rel-6 | Michael |  | DRM |  |  | TSG |
| 225 | 31.1 | Requirements | 179d | 2001-10-08 A | 2002-06-13 A | 100% |  | 2001-10-08 | 2002-06-13 | 179d |  | finish no earlier than 2002-06-13 | S1 | 1432h | 1432h |  | Rel-6 |  |  |  | Nicholas Wood, Openwave Systems | nicholas.wood@openwave.com |  |
| 226 | 28.2 | Monitoring of Stages 2 and 3 progress (actual work to be done by OMA) | 155d? | 2002-08-19 A | 2003-03-21 | 20% | 124d? | 2002-08-19 | 2003-03-21 | 155d? | 582d | start no earlier than 2002-08-19 | S1 | 1240h | 248h |  | Rel-6 |  |  |  |  |  |  |
| 227 | 31.3 | Monitoring of Security (work done by OMA) | 186d | 2002-06-17 A | 2003-03-03 | 40% | 111.6d | 2002-06-17 | 2003-03-03 | 186d | 596d | finish no earlier than 2003-03-03 | S3 | 1488h | 595.2h |  | Rel-6 |  |  |  |  |  |  |
| 228 | 28.4 | Stage 2 | 107d? | 2004-01-01 | 2004-05-28 |  |  |  |  |  | 272d | finish no earlier than 2004-05-28 | OMA | 856h |  |  | Rel-6 |  |  |  |  | OMA-LIAISON@mail.openmobilealliance.org |  |
| 229 | 28.5 | Stage 3 | 107d? | 2004-01-01 | 2004-05-28 |  |  |  |  |  | 272d | finish no earlier than 2004-05-28 | OMA | 856h |  |  | Rel-6 |  |  |  |  | OMA-LIAISON@mail.openmobilealliance.org |  |
| 230 | 32 | **WLAN-UMTS Interworking** | 1239d? | 2000-01-03 A | 2004-09-30 | 86% | 170.84d? | 2000-01-03 | 2003-12-12 | 1030d? | 183d |  | S1 | 42896h | 36981.3h |  | Rel-6 | Michael |  | WLAN | Fredric Paint, Telenor | frederic.paint@telenor.com | TSG |
| 231 | 32.1 | Technical Report | 900d? | 2000-01-03 A | 2003-06-13 A | 100% |  | 2000-01-03 | 2003-06-13 | 900d? |  | finish no earlier than 2003-06-13 | S1 | 7200h | 7200h | 22.934, 22.101, 22.105 | Rel-6 |  |  | WLAN-TR | Fredric Paint, Telenor | frederic.paint@telenor.com |  |
| 232 | 29.2 | Stage 1 | 1160d? | 2000-01-03 A | 2004-06-11 | 99% | 11.6d? | 2000-01-03 | 2003-06-13 | 900d? | 262d | finish no earlier than 2004-06-11 | S1 | 9280h | 9187.2h | 22.234 | Rel-6 |  |  | WLAN-TS | Fredric Paint, Telenor | frederic.paint@telenor.com |  |
| 233 | 32.2 | Architecture Definition for scenarii 2 and 3 | 571d | 2002-03-25 A | 2004-05-31 A | 100% |  | 2002-03-25 | 2003-09-26 | 395d |  | finish no earlier than 2004-05-31 | S2 | 4568h | 4568h |  | Rel-6 |  |  |  |  |  | TSG |
| 234 | 32.3 | Security | 125d | 2002-09-30 A | 2003-03-21 | 30% | 87.5d | 2002-09-30 | 2003-03-21 | 125d | 582d | finish no earlier than 2003-03-21 | S3 | 1000h | 300h | 21.133, 33.106, 33.107, 33.108, 33.200, 33.203, 33.210 | Rel-6 |  |  |  | Lopez-Soria, Luis, Ericsson | luis.lopez-soria@ece.ericsson.se | TSG |
| 235 | 29.5 | Stage 3 - CN4 aspects | 334d? | 2003-05-23 A | 2004-09-01 | 77% | 76.82d? | 2003-05-23 | 2003-12-12 | 146d? | 204d | finish no earlier than 2004-09-01 | N4 | 2672h | 2057.44h | 29.234, 29.061 | Rel-6 |  |  | WLAN-IW | Rodriguez ,Raquel, Nokia | raquel.rodriguez@nokia.com | TSG |
| 236 | 29.6 | Stage 3 - CN3 aspects (Wi Interface for Scenario 3) | 355d? | 2003-05-23 A | 2004-09-30 | 68% | 114.6d? |  |  |  | 183d | start no earlier than 2003-05-23 | N3 | 2840h | 1923.2h | 29.161 | Rel-6 |  |  | WLAN |  |  | TSG |
| 237 | 29.7 | Stage 3 for scenario 2 | 339d? | 2003-05-23 A | 2004-09-08 | 78% | 74.58d? | 2003-05-23 | 2003-12-12 | 146d? | 199d | finish no earlier than 2004-09-08 | N1 | 2712h | 2115.36h |  | Rel-6 |  |  |  |  |  | WG |
| 238 | 29.8 | Stage 3 for scenario 3 | 339d? | 2003-05-23 A | 2004-09-08 | 40% | 203.4d? |  |  |  | 199d | start no earlier than 2003-05-23 | N1 | 2712h | 1084.8h |  | Rel-6 |  |  |  |  |  | WG |

Notes:
- 222: 17 May no activity in CN4.........
- 223: WID approved SA#17. SA WG3 progress slow, depends on progress in other groups.
- 224: Foreseen start and completion dates introduced by MCC (no indication at all on the WID)
- 227: SA3 acknowledge role in WI at SA3#20. Active contribution S3#24, S3#25. S3 WID approved SA#17
- 234: Active contribution S3#24, S3#25. WID approved SA#17
- 235: WID approved at CN#19............
- 236: WID approved at CN#19.........

| ID | WBS | Task | Duration | Start | Finish | Complete | Remaining | Baseline start | Baseline finish | Baseline duration | Total slack | Constraint | Resources | Work | Actual work | Text1 | Text6 | Text7 | Text8 | Text3 | Text4 | Text5 | Text9 | Text10 | Text11 | Text12 |
| --- | --- | --- | --- | --- | --- | --- | --- | --- | --- | --- | --- | --- | --- | --- | --- | --- | --- | --- | --- | --- | --- | --- | --- | --- | --- | --- |
| 239 | 33 | **Priority Service** | 666d? | 2002-05-30 A | 2004-12-16 | 61% | 260.04d? | 2002-05-30 | 2003-09-26 | 347d? | 128d |  | S1 | 12616h | 7690.01h | PRIOR | Rel-6 | TSG | Michael |  |  |  |  |  |  |  |
| 240 | 33.1 | Feasibility Study | 1d | 2002-06-14 A | 2002-06-14 A | 100% |  | 2002-06-14 | 2002-06-14 | 1d |  | finish no earlier than 2002-06-14 | S1 | 8h | 8h | PRIOR-FS | Rel-6 |  | Michael | 22.950 | Biplab K. Pramanik, Telcordia Technologies | bpramani@telcordia.com |  |  |  |  |
| 241 | 33.2 | Stage 1 - Requirements | 340d | 2002-05-30 A | 2003-09-17 A | 100% |  | 2002-05-30 | 2003-09-17 | 340d |  | finish no earlier than 2003-09-17 | S1 | 2720h | 2720h | PRIOR-SR | Rel-6 |  | Michael |  | James J. Garrahan, Telcordia Technologies | bpramani@telcordia.com |  |  |  |  |
| 242 | 30.3 | Multimedia Priority Service | 450d? | 2003-03-28 A | 2004-12-16 | 20% | 360d? | 2003-03-28 | 2003-09-26 | 131d? | 128d | finish no earlier than 2004-12-16 | S1 | 3600h | 720h |  | Rel-6 |  |  |  |  |  |  |  |  |  |
| 243 | 30.4 | Priority service implementation guide | 131d? | 2003-03-28 A | 2003-09-26 A | 100% |  | 2003-03-28 | 2003-09-26 | 131d? |  | finish no earlier than 2003-09-26 | S1 | 1048h | 1048h |  | Rel-6 |  |  | 22.952 | Biplab K. Pramanik, Telcordia Technologies | bpramani@telcordia.com |  |  |  |  |
| 244 | 34 | **Network Sharing** | 563.41d? | 2003-01-20 A | 2005-03-17 | 65% | 199.17d? | 2003-01-20 | 2003-12-19 | 240d? | 63.59d |  | S1 | 17134.5h | 11077.2h | NTShar | Rel-6 | TSG | Michael |  |  |  |  |  |  |  |
| 245 | 34.1 | Technical Report | 240d? | 2003-01-20 A | 2003-12-19 A | 100% |  | 2003-01-20 | 2003-12-19 | 240d? |  |  | S1 | 1920h | 1920h | NTShar-TR | Rel-6 |  | Michael | 22.951 |  |  |  |  |  |  |
| 246 | 31.2 | Stage 1 - CRs to implement Network Sharing | 240d? | 2003-01-20 A | 2003-12-19 A | 100% |  | 2003-01-20 | 2003-12-19 | 240d? |  | finish no earlier than 2003-12-19 | S1 | 1920h | 1920h | NTShar-CR | Rel-6 |  |  | 22.011, 22.101, 22.115, 22.129 |  |  |  |  |  |  |
| 247 | 31.3 | Stage 2 | 372d? | 2003-02-27 A | 2004-07-30 | 83% | 63.24d? | 2003-02-27 | 2003-12-19 | 212d? | 227d | finish no earlier than 2004-07-30 | S2 | 2976h | 2470.08h |  | Rel-6 |  |  |  |  |  |  |  |  |  |
| 248 | 31.4 | Network sharing - stage 3 | 339d? | 2003-05-23 A | 2004-09-08 | 40% | 203.4d? | 2003-05-23 | 2003-12-12 | 146d? | 199d | finish no earlier than 2004-09-08 | N1 | 2712h | 1084.8h |  | Rel-6 | WG |  |  |  |  |  |  |  |  |
| 249 | 31.5 | Enhancement of the support of network sharing in the UTRAN | 389.41d | 2003-09-19 A | 2005-03-17 | 25% | 292.05d |  |  |  | 63.59d | finish no earlier than 2005-03-17 | R2 | 3115.25h | 778.81h | NTShar-UTRANEnh | Rel-6 | TSG | MCC_RAN | TS25.401, TS25.413, TS25.331, TS25.304 | Anders Dahlén, TeliaSonera | Anders.Dahlen@TeliaSonera.com | BB | 31018 | Active | 48 |
| 250 | 35 | **QoS Improvements** | 565d? | 2002-07-15 A | 2004-09-10 | 89% | 64.47d? | 2000-01-03 | 2003-12-19 | 1035d? | 197d |  | S2 | 12120h | 10737h | QoS1 | Rel-6 | TSG | Sang-Ui |  |  |  |  |  |  |  |
| 251 | 35.1 | FS on Dynamic Policy control enhancements for end-to-end QoS | 465d | 2002-07-15 A | 2004-04-23 A | 100% |  | 2002-07-15 | 2003-12-19 | 375d |  | finish no earlier than 2004-04-23 | S2 | 3720h | 3720h | QoS1 | Rel-6 | TSG |  |  |  | Claire Mousset, Nortel |  |  |  |  |
| 252 | 32.2 | Definition of the Gq interface | 214d? | 2003-07-01 A | 2004-04-23 A | 100% |  | 2000-01-03 | 2000-01-03 | 1d? |  | finish no earlier than 2004-04-23 | S2 | 1712h | 1712h |  | Rel-6 |  |  |  | Janne Rinne (Nokia) |  |  |  |  |  |
| 253 | 32.3 | Gq interface specification for Dynamic Policy control enhancements – Stage 3 | 271d | 2003-08-29 A | 2004-09-10 | 60% | 108.4d |  |  |  | 197d | finish no earlier than 2004-09-10 | N3 | 2168h | 1300.8h |  | Rel-6 | TSG |  | 24,228, 29.207, 29.208 | Anna Sillanpää, Nokia | Anna.Sillanpaai@nokia.com |  |  |  |  |
| 254 | 36 | **Subscriber certificates** | 722d? | 2002-02-25 A | 2004-11-30 | 54% | 332.49d? | 2002-02-25 | 2002-11-14 | 189d | 140d |  | S3 | 12320h | 6646.47h | SEC1-SC | Rel-6 | TSG | Maurice | 33.102 | Valtteri Niemi, Nokia | valtteri.niemi@nokia.com |  |  |  |  |
| 255 | 36.1 | Stage 1 | 144d | 2002-02-25 A | 2002-09-12 | 40% | 86.4d | 2002-02-25 | 2002-09-12 | 144d | 718d | finish no earlier than 2002-09-12 | S3 | 1152h | 460.8h |  | Rel-6 |  |  |  |  |  |  |  |  |  |
| 256 | 36.2 | Architecture review | 24d | 2002-10-14 A | 2002-11-14 A | 100% |  | 2002-10-14 | 2002-11-14 | 24d |  | finish no earlier than 2002-11-14 | S2 | 192h | 192h |  | Rel-6 |  |  |  |  |  |  |  |  |  |
| 257 | 33.3 | Stage 3 | 313d? | 2003-09-19 A | 2004-11-30 | 50% | 156.5d? |  |  |  | 140d | finish no earlier than 2004-11-30 | N4 | 2504h | 1252h | SEC1-SC | Rel-6 |  | Kimmo |  | Lauri Laitinen, Nokia |  |  |  |  |  |
| 258 | 33.4 | Stage 3 Ua & Ub interfaces | 223d? | 2003-11-03 A | 2004-09-08 | 40% | 133.8d? |  |  |  | 199d | finish no earlier than 2004-09-08 | N1 | 1784h | 713.6h |  | Rel-6 |  |  |  |  |  |  |  |  |  |
| 259 | 33.5 | OMA dependencies on Subscriber certificates | 114d? | 2004-01-01 A | 2004-06-08 A | 100% |  |  |  |  |  | finish no earlier than 2004-06-08 | OMA | 912h | 912h |  | Rel-6 | n/a |  |  |  | OMA-LIAISON@mail.openmobilealliance.org |  |  |  |  |
| 260 | 34 | **Rel-6 OSA enhancements** | 501d? | 2002-10-31 A | 2004-09-30 | 68% | 162.14d? | 2002-02-14 | 2003-12-19 | 481.85d? | 183d |  | S1 | 23727.2h | 14688.3h | OSA3 | Rel-6 | TSG | Adrian | 22.127, 29.198, 29.998 | Chelo ABARCA (Alcatel) | Chelo.Abarca@alcatel.fr |  |  |  |  |
| 261 | 34.1 | Scope of the Open Service Access Release 6 | 66d? | 2003-03-28 A | 2003-06-27 A | 100% |  | 2003-03-28 | 2003-06-27 | 66d? |  | finish no earlier than 2003-06-27 | S1 | 528h | 528h |  | Rel-6 | TSG |  |  |  |  |  |  |  |  |
| 262 | 34.2 | Multi Media Messaging function | 427d? | 2002-10-31 A | 2004-06-18 | 50% | 213.5d? | 2002-10-31 | 2003-12-19 | 297d? | 257d | finish no earlier than 2004-06-18 | N5 | 3416h | 1708h |  | Rel-6 | TSG |  | 29.198, 29.998 |  |  |  |  |  |  |
| 263 | 34.3 | Policy management extensions | 292d? | 2002-10-31 A | 2003-12-12 A | 100% |  | 2002-10-31 | 2003-12-19 | 297d? |  | finish no earlier than 2003-12-12 | N5 | 2336h | 2336h |  | Rel-6 | TSG |  | 29.198, 29.998 |  |  |  |  |  |  |
| 264 | 34.4 | TS on Presence and Availability Management (from the PRESNC WI) | 367d? | 2002-10-31 A | 2004-03-26 A | 100% |  | 2002-10-31 | 2003-12-19 | 297d? |  | finish no earlier than 2004-03-26 | N5 | 2936h | 2936h |  | Rel-6 | TSG |  | 29.198-14 |  |  |  |  |  |  |
| 265 | 34.5 | OSA interfaces at different levels of abstractions (Parlay X, Web services) | 245d? | 2003-07-14 A | 2004-06-18 | 90% | 24.5d? | 2003-03-14 | 2003-12-19 | 201d? | 257d | finish no earlier than 2004-02-27 | N5 | 1960h | 1764h |  | Rel-6 | TSG |  | 29.199 |  |  |  |  |  |  |
| 266 | 34.6 | Introduction of migration support mechanism | 290d? | 2002-10-31 A | 2003-12-10 A | 100% |  | 2003-03-14 | 2003-12-19 | 201d? |  | finish no earlier than 2003-12-12 | N5 | 2320h | 2320h |  | Rel-6 | TSG |  | 29.198, 29.998 |  |  |  |  |  |  |
| 267 | 34.7 | User Profile | 367d? | 2003-01-23 | 2004-06-18 |  |  | 2003-03-14 | 2003-12-19 | 201d? | 257d | start no earlier than 2003-01-23 | N5 | 2936h |  |  | Rel-6 | TSG |  | 29.198, 29.998 |  |  |  |  |  |  |
| 268 | 34.8 | Framework Function for Federation | 225d? | 2003-02-03 A | 2003-12-12 A | 100% |  | 2003-03-14 | 2003-12-19 | 201d? |  | finish no earlier than 2003-12-12 | N5 | 1800h | 1800h |  | Rel-6 | TSG |  | 29.198, 29.998 |  |  |  |  |  |  |
| 269 | 34.9 | OMA dependencies on OSA | 196d? | 2004-01-01 | 2004-09-30 |  |  |  |  |  | 183d | start no earlier than 2004-01-01 | OMA | 1568h |  |  | Rel-6 | n/a |  |  |  | OMA-LIAISON@mail.openmobilealliance.org |  |  |  |  |

Notes:
- 253: [DAB - 25.05.04] - Delayed to Sept - possibly Dec 2004
- 254: Approved at SA#14. This may require BBs from CN1, CN4, SA5 and T3
- 255: Contribution received S3#24, S3#25
- 257: WID approved at CN#21............
- 259: Updated according to SP-040420
- 260: NP-040144 Rev WID replaces NP-040068.
- 264: N5#26: Split WI into TS & TR.
- 265: N5#26: Will be submitted to CN#24 for Approval only if Rel-6 "freezing" is 06/2004.
- 267: N5#24&25&26: Still Pending input from SA1/2.
- 269: Updated according to SP-040420

| ID | WBS | Task | Duration | Start | Finish | Complete | Remaining | Baseline start | Baseline finish | Baseline duration | Total slack | Constraint | Resources | Work | Actual work | Text1 | Text4 | Text6 | Text7 | Text8 | Text3 | Text5 | Text2 |
| --- | --- | --- | --- | --- | --- | --- | --- | --- | --- | --- | --- | --- | --- | --- | --- | --- | --- | --- | --- | --- | --- | --- | --- |
| 270 | 39 | **Addition of frequency bands to GSM** | 621d | 2002-06-28 A | 2004-11-12 | 4% | 596.04d | 2002-06-28 | 2003-08-29 | 306d | 152d |  | GP | 15320h | 615.64h | TAPS | Torben Themsen | Rel-6 | TSG | Paolo |  |  |  |
| 271 | 39.1 | **Addition of frequency bands to GSM – Changes to core specs** | 26d | 2002-11-15 A | 2002-12-20 A | 100% |  | 2002-11-15 | 2002-12-20 | 26d |  |  | G1 | 416h | 416h | TAPS-Specs | Torben Themsen | Rel-6 | TSG |  |  |  |  |
| 272 | 39.1.1 | Changes to core specs | 26d | 2002-11-15 A | 2002-12-20 A | 100% |  | 2002-11-15 | 2002-12-20 | 26d |  | finish no earlier than 2002-12-20 | G1 | 208h | 208h |  |  | Rel-6 |  |  |  |  |  |
| 273 | 39.2 | **Addition of frequency bands to GSM – Changes for conformance tests** | 621d | 2002-06-28 | 2004-11-12 |  |  | 2002-06-28 | 2003-08-29 | 306d | 152d |  | G4 | 9936h |  | TAPS-Conf | Torben Themsen | Rel-6 |  |  |  |  |  |
| 274 | 39.2.1 | 51.010-1 Add testing | 621d | 2002-06-28 | 2004-11-12 |  |  | 2002-06-28 | 2003-08-29 | 306d | 152d | finish no earlier than 2004-11-12 | G4 | 4968h |  |  |  | Rel-6 |  |  |  |  |  |
| 275 | 40 | **Seamless support of streaming services in A/Gb mode** | 1065d? | 2000-01-03 A | 2004-01-30 | 94% | 68.97d? | 2000-01-03 | 2003-12-19 | 1035d? | 357d |  | GP | 40840h | 37411.7h | SSStrea | José Luis Carrizo Martínez, Vodafone | Rel-6 | TSG | Paolo |  |  |  |
| 276 | 40.1 | **Identification of requirements for streaming** | 46d? | 2003-06-27 A | 2003-08-29 A | 100% |  | 2003-06-27 | 2003-06-27 | 1d? |  |  | G1 | 736h | 736h |  |  | Rel-6 |  |  |  |  |  |
| 277 | 36.1.1 | Requirements | 46d? | 2003-06-27 A | 2003-08-29 A | 100% |  | 2003-06-27 | 2003-06-27 | 1d? |  | finish no earlier than 2003-08-29 | G1 | 368h | 368h |  |  | Rel-6 |  |  |  |  |  |
| 278 | 40.2 | **Performance study of cell change mechanisms** | 955d? | 2000-01-03 A | 2003-08-29 A | 100% |  | 2000-01-03 | 2003-06-27 | 910d? |  |  | G1 | 30560h | 30560h |  |  | Rel-6 |  |  |  |  |  |
| 279 | 36.2.1 | Performance of NACC | 955d? | 2000-01-03 A | 2003-08-29 A | 100% |  | 2000-01-03 | 2003-06-27 | 910d? |  | finish no earlier than 2003-08-29 | G1 | 7640h | 7640h |  |  | Rel-6 |  |  |  |  |  |
| 280 | 36.2.2 | Performance of cell change in DTM for the PS domain | 955d? | 2000-01-03 A | 2003-08-29 A | 100% |  | 2000-01-03 | 2003-06-27 | 910d? |  | finish no earlier than 2003-08-29 | G1 | 7640h | 7640h |  |  | Rel-6 |  |  |  |  |  |
| 281 | 36.2.3 | Handover | 955d? | 2000-01-03 A | 2003-08-29 A | 100% |  | 2000-01-03 | 2003-06-27 | 910d? |  | finish no earlier than 2003-08-29 | G1 | 7640h | 7640h |  |  | Rel-6 |  |  |  |  |  |
| 282 | 40.3 | **Reduction of service interruption times and packet loss during mobility procedures** | 106d? | 2003-06-27 A | 2003-11-21 | 99% | 0d? | 2003-06-27 | 2003-06-27 | 1d? | 0d |  | G2 | 4240h | 3396h |  |  | Rel-6 |  |  |  |  |  |
| 283 | 36.3.1 | Optimisations of existing mechanisms/procedures | 106d? | 2003-06-27 A | 2003-11-21 A | 100% |  | 2003-06-27 | 2003-06-27 | 1d? |  | finish no earlier than 2003-11-21 | G2 | 848h | 848h |  |  | Rel-6 |  |  |  |  |  |
| 284 | 36.3.2 | Inter-system NACC | 106d? | 2003-06-27 A | 2003-11-21 A | 100% |  | 2003-06-27 | 2003-06-27 | 1d? |  | finish no earlier than 2003-11-21 | G2 | 848h | 848h |  |  | Rel-6 |  |  |  |  |  |
| 285 | 36.3.3 | PS Handover (within GERAN and between GERAN and UTRAN) | 106d? | 2003-06-27 A | 2003-11-21 A | 100% |  | 2003-06-27 | 2003-06-27 | 1d? |  | finish no earlier than 2003-11-21 | G2 | 848h | 848h |  |  | Rel-6 |  |  |  |  |  |
| 286 | 36.3.4 | Dependency to other features | 106d? | 2003-06-27 A | 2003-11-21 A | 100% |  | 2003-06-27 | 2003-06-27 | 1d? |  | finish no earlier than 2003-11-21 | G2 | 848h | 848h |  |  | Rel-6 |  |  |  |  |  |
| 287 | 40.5 | **MS conformance testing** | 31d? | 2003-12-19 A | 2004-01-30 A | 100% |  | 2003-12-19 | 2003-12-19 | 1d? |  |  | G3 | 248h | 248h |  |  | Rel-6 |  |  |  |  |  |
| 288 | 36.4.1 | MS conformance tests | 31d? | 2003-12-19 A | 2004-01-30 A | 100% |  | 2003-12-19 | 2003-12-19 | 1d? |  | finish no earlier than 2004-01-30 | G4,G5 | 248h | 248h |  |  | Rel-6 |  |  |  |  |  |
| 289 | 36.5 | GERAN A/Gb mode security enhancements | 261d? | 2002-09-26 A | 2003-09-25 | 10% | 234.9d? | 2002-09-26 | 2003-09-25 | 261d? | 448d | finish no earlier than 2003-09-25 | S3 | 2088h | 208.8h |  | Peter Howard, Vodafone | Rel-6 |  |  | 33.102 | peter.howard@vodafone.com |  |
| 290 | 41 | Performance characterisation of default codecs for PS conversational multimedia application | 455d | 2002-09-13 A | 2004-06-10 A | 100% |  | 2002-09-13 | 2003-09-26 | 271d |  | finish no earlier than 2004-06-10 | S4 | 3640h | 3640h | CODCAR | Pasi Ojala (Nokia) | Rel-6 | TSG | Paolo | TR 26.935 | pasi.s.ojala@nokia.com |  |
| 291 | 43 | Study on Privacy Capability | 83d | 2003-11-10 A | 2004-03-03 | 85% | 12.45d | 2002-11-08 | 2003-03-03 | 82d | 334d | start no earlier than 2003-11-10 | S1 | 664h | 564.4h | PrivCap | Liz Daniel, Lucent | Rel-6 | TSG | Michael | TR 21.xyz |  |  |
| 292 | 44 | **OAM&P** | 585d? | 2002-09-12 A | 2004-12-08 | 67% | 190.64d? | 2002-05-21 | 2004-03-18 | 477.3d? | 134d |  | S5 | 28341.6h | 17376.1h | OAM | Michael TRUSS (Motorola) | Rel-6 | TSG | Adrian | 32-series | Michael.Truss@MOTOROLA.COM |  |
| 293 | 44.1 | Principles, high level Requirements and Architecture | 526d | 2002-09-12 A | 2004-09-16 | 75% | 131.5d | 2002-09-12 | 2004-03-18 | 396d | 193d | finish no earlier than 2004-09-16 | S5 | 4208h | 3156h | OAM-AR | Michael TRUSS (Motorola) | Rel-6 | TSG |  | 32.101, 32.102 | Michael.Truss@MOTOROLA.COM | BCaM |
| 294 | 44.2 | Performance Management | 526d | 2002-09-12 A | 2004-09-16 | 75% | 131.5d | 2002-09-12 | 2004-03-18 | 396d | 193d | finish no earlier than 2004-09-16 | S5 | 4208h | 3156h | OAM-PM | Christian TOCHE (Nortel Networks) | Rel-6 | TSG |  | 32.41x, 52.402 | toche@NORTELNETWORKS.COM | BCaM |
| 295 | 44.4 | Network Infrastructure Management | 526d | 2002-09-12 A | 2004-09-16 | 75% | 131.5d | 2002-09-12 | 2004-03-18 | 396d | 193d | finish no earlier than 2004-09-16 | S5 | 4208h | 3156h | OAM-NIM | Thomas TOVINGER (Ericsson) | Rel-6 | TSG |  | 32.15x, 32.3/6/7xy | Thomas.Tovinger@emw.ericsson.se |  |

Notes:
- 271: Ready
- 273: Not started
- 276: Started
- 278: Started
- 282: Completed at GERAN#17
- 287: Closed, no work needed
- 288: Closed, no work needed
- 289: Possible changes to 33.102 or new specification needed.
- 292: az: SA#23 TSG approval 06/04->09/04

| ID | WBS | Task | Duration | Start | Finish | Complete | Remaining | Baseline start | Baseline finish | Baseline duration | Total slack | Constraint | Resources | Work | Actual work | Text1 | Text3 | Text4 | Text5 | Text6 | Text7 | Text8 | Text2 | Text9 |
| --- | --- | --- | --- | --- | --- | --- | --- | --- | --- | --- | --- | --- | --- | --- | --- | --- | --- | --- | --- | --- | --- | --- | --- | --- |
| 296 | 44.5 | **Trace Management** | 579d? | 2002-09-20 A | 2004-12-08 | 55% | 257.94d? | 2003-06-06 | 2003-09-19 | 76d | 134d |  | S5 | 11160h | 4835.68h | OAM-Trace | 32.42x, 52.008 | Kari RÖNKÄ (Nokia) | kari.t.ronka@nokia.com | Rel-6 | TSG |  |  |  |
| 297 | 39.4.1 | Subscriber and UE trace management | 520d | 2002-09-20 A | 2004-09-16 | 75% | 130d |  |  |  | 193d | finish no earlier than 2004-09-16 | S5 | 4160h | 3120h | OAM-Trace | 32.42x, 52.008 | Kari RÖNKÄ (Nokia) | kari.t.ronka@nokia.com | Rel-6 | TSG |  |  |  |
| 298 | 39.4.2 | Subscriber and equipment trace in UTRAN | 268d? | 2003-06-06 A | 2004-06-15 | 60% | 107.2d? | 2003-06-06 | 2003-09-19 | 76d? | 260d | finish no earlier than 2004-06-15 | R3 | 2144h | 1286.4h | OAM-Trace-RAN |  | Yann Sehedi, Nortel | sehedic@nortelnetworks.com | Rel-6 | TSG | MCC_RAN |  |  |
| 299 | 39.4.3 | SIP enhancements for trace | 213d? | 2004-02-16 A | 2004-12-08 | 2% | 208.74d? |  |  |  | 134d | finish no earlier than 2004-12-08 | N1 | 1704h | 34.08h |  |  |  |  | Rel-6 |  |  |  |  |
| 300 | 40 | **Charging Management** | 476d? | 2002-11-21 A | 2004-09-16 | 78% | 106.33d? | 2002-11-21 | 2004-03-18 | 346d? | 193d |  | S5 | 20416h | 13742.5h | CH | 32.2xy | Karl-Heinz NENNER (T-Mobile) | karl-heinz.nenner@t-mobile.de | Rel-6 | TSG | Adrian |  |  |
| 301 | 40.1 | Charging Management for Bearer level | 390d? | 2003-03-21 A | 2004-09-16 | 75% | 97.5d? | 2002-11-22 | 2004-03-18 | 345d? | 193d | finish no earlier than 2004-09-16 | S5 | 3120h | 2340h | CH-BC |  | Benni ALEXANDER (Nokia) |  | Rel-6 | TSG |  |  |  |
| 302 | 40.2 | Charging Management for the IMS | 390d? | 2003-03-21 A | 2004-09-16 | 75% | 97.5d? | 2002-11-22 | 2004-03-18 | 345d? | 193d | finish no earlier than 2004-09-16 | S5 | 3120h | 2340h | CH-IC |  | Patrik TEPPO (Ericsson) |  | Rel-6 | TSG |  |  |  |
| 303 | 40.3 | Charging Management for the Service domain | 390d? | 2003-03-21 A | 2004-09-16 | 75% | 97.5d? | 2002-11-22 | 2004-03-18 | 345d? | 193d | finish no earlier than 2004-09-16 | S5 | 3120h | 2340h | CH-SC |  | Gerald GÖRMER (Siemens) |  | Rel-6 | TSG |  |  |  |
| 304 | 40.4 | **Overall architectural aspects of IP flow based bearer level charging** | 442d? | 2002-11-21 A | 2004-07-30 | 84% | 69.06d? | 2002-11-21 | 2003-09-26 | 222d? | 227d |  | S2 | 7248h | 5109.28h | CH-FBC |  |  |  | Rel-6 |  |  |  |  |
| 305 | 40.4.1 | Overall definition of FBC architecture | 334d? | 2002-11-21 A | 2004-03-02 | 99% | 1d? |  |  |  | 335d | start no earlier than 2002-11-21 | S2 | 2672h | 2664h |  |  |  |  | Rel-6 |  |  |  |  |
| 306 | 40.4.2 | Study on providing policy control with FBC | 130d? | 2004-02-02 A | 2004-07-30 | 45% | 71.5d? |  |  |  | 227d | start no earlier than 2004-02-01 | S2 | 1040h | 468h |  |  |  |  | Rel-6 |  |  |  |  |
| 307 | 13 | **Rel-6 UICC/USIM enhancements and interworking** | 889d | 2000-09-25 A | 2004-02-19 | 99% | 8.4d | 2000-09-25 | 2003-09-17 | 778d | 343d |  | T3 | 26760h | 23288.6h | USAT1 |  |  |  | Rel-6 | TSG | Claus | Ter | 1800 |
| 308 | 13.1 | **UICC API** | 502d | 2002-03-20 A | 2004-02-19 | 98% | 10.73d | 2002-03-20 | 2003-09-17 | 391d | 343d |  | T3 | 8584h | 8400.59h | USAT1-API |  |  |  | Rel-6 |  |  | Ter | 1802 |
| 309 | 13.1.1 | Java API Test specification | 59d | 2002-03-20 A | 2002-06-10 A | 100% |  | 2002-03-20 | 2002-09-20 | 133d |  | finish no earlier than 2002-09-20 | T3 | 472h | 472h |  |  | Mario Pérez (Microelectrónica Española) |  | Rel-6 |  |  |  |  |
| 310 | 13.1.2 | Java API Test specification (TS 43.019 Rel-5) | 268d | 2002-05-30 A | 2003-06-09 A | 100% |  | 2002-05-30 | 2003-09-17 | 340d |  | finish no earlier than 2003-09-17 | T3 | 2144h | 2144h |  |  | Mario Pérez (Microelectrónica Española) |  | Rel-6 |  |  |  |  |
| 311 | 41.1.3 | 2G/3G Java Card™ API based applet interworking | 244d | 2003-03-17 A | 2004-02-19 | 95% | 12.2d |  |  |  | 343d | finish no earlier than 2004-02-19 | T3 | 1952h | 1854.4h | USAT1-API |  | Stéphane Andrau-Oberthur Card Systems |  | Rel-6 | TSG | Claus |  |  |
| 312 | 41.2 | **Rel-6 USIM toolkit enhancements** | 525d | 2000-09-25 A | 2002-09-27 | 99% | 0d | 2000-09-25 | 2002-09-27 | 525d | 0d |  | T3 | 14160h | 10910h |  |  |  |  | Rel-6 |  | Claus |  |  |
| 313 | 41.2.1 | **C SIM API** | 525d | 2000-09-25 A | 2002-09-27 A | 100% |  | 2000-09-25 | 2002-09-27 | 525d |  |  | T3 | 9960h | 9960h | USAT1-API-MULTOS |  |  |  | Rel-6 | TSG |  | Ter | 2031 |
| 314 | 41.2.1.1 | Specification | 525d | 2000-09-25 A | 2002-09-27 A | 100% |  | 2000-09-25 | 2002-09-27 | 525d |  | finish no earlier than 2002-09-27 | T3 | 4200h | 4200h |  |  | Neil Livingston – Aspects Software |  | Rel-6 | TSG |  | Ter | 2032 |
| 315 | 41.2.1.2 | Test specification | 195d | 2001-01-01 A | 2001-09-28 A | 100% |  | 2001-01-01 | 2001-09-28 | 195d |  | finish no earlier than 2001-09-28 | T3 | 1560h | 1560h |  |  | Neil Livingston – Aspects Software |  | Rel-6 | TSG |  | Ter | 2033 |
| 316 | 42 | **Packet Switched Streaming Services Rel-6** | 479d? | 2002-11-18 A | 2004-09-16 | 92% | 40.36d? | 2002-11-18 | 2003-12-19 | 285d? | 193d |  | S4 | 8200h | 7509.16h | PSSrel6 |  | Olle Franceschi (Ericsson) | olle.franceschi@ericsson.com | Rel-6 | TSG | Paolo |  |  |
| 317 | 42.1 | Stage 1 | 86d? | 2002-11-18 A | 2003-03-17 A | 100% |  | 2002-11-18 | 2003-03-17 | 86d? |  | finish no earlier than 2003-03-17 | S1 | 688h | 688h |  | 22.233 |  |  | Rel-6 | TSG |  |  |  |
| 318 | 42.2 | Stage 3 | 460d? | 2002-12-13 A | 2004-09-16 | 90% | 46d? | 2002-12-13 | 2003-12-19 | 266d? | 193d | finish no earlier than 2004-09-16 | S4 | 3680h | 3312h | PSSrel6-Stage3 | 26.233, 26.234, 26.244, 26.245, 26.246 | Olle Franceschi (Ericsson) | olle.franceschi@ericsson.com | Rel-6 | WG | Paolo |  |  |
| 319 | 43 | AMR-WB extension for high audio quality | 390d | 2002-12-13 A | 2004-06-10 | 95% | 19.5d | 2002-12-13 | 2003-09-26 | 206d | 263d | finish no earlier than 2004-06-10 | S4 | 3120h | 2964h | AMRWB+ |  | Janne Vainio (Nokia) | janne.m.vainio@nokia.com | Rel-6 | TSG | Paolo |  |  |
| 320 | 44 | Codec Enhancements for Packet Switched Conversational Multimedia Applications | 133d? | 2004-03-16 A | 2004-09-16 | 20% | 106.4d? |  |  |  | 193d | finish no earlier than 2004-09-16 | S4 | 1064h | 212.8h | CEPSCM | 26.235, 26.236 | Miska Hannuksela (Nokia) | miska.hannuksela@nokia.com | Rel-6 | WG | Paolo |  |  |
| 321 | 45 | 3G-324M Improvements | 133d? | 2004-03-16 A | 2004-09-16 | 40% | 79.8d? |  |  |  | 193d | finish no earlier than 2004-09-16 | S4 | 1064h | 425.6h | 3G-324MI | 26.111, 26.911 | Bo Burman, Ericsson | bo.burman@ericsson.com | Rel-6 | WG | Paolo |  |  |
| 322 | 46 | Single Antenna Receiver Interference Cancellation (SAIC) | 375.92d? | 2002-11-15 A | 2004-06-25 | 80% | 75.18d? | 2002-11-15 | 2003-11-21 | 220.92d? | 252d | finish no earlier than 2004-06-25 | GP; G1 | 6014.72h | 4811.77h | SAIC |  | Marc Grant, Cingular Wireless |  | Rel-6 | TSG |  |  |  |

Notes:
- 300: az: SA#23 TSG approval 06/04->09/04
- 308: 8/3/2001: test spec is based on R99 core spec, so deleted from Workplan
- 317: 2nd resp SA4

| ID | WBS | Task | Duration | Start | Finish | Complete | Remaining | Baseline start | Baseline finish | Baseline duration | Total slack | Constraint | Resources | Work | Actual work | Text1 | Text4 | Text5 | Text6 | Text7 | Text8 | Text3 |
| --- | --- | --- | --- | --- | --- | --- | --- | --- | --- | --- | --- | --- | --- | --- | --- | --- | --- | --- | --- | --- | --- | --- |
| 323 | 47 | **Support of Conversational Services in A/Gb mode via the PS domain** | 406d? | 2003-02-07 A | 2004-08-27 | 28% | 292.78d? | 2003-02-07 | 2004-04-23 | 316d? | 207d |  | GP | 13512h | 2258.93h | SCSAGB | David Bladsjö, Ericsson | david.bladsjo@ericsson.com | Rel-6 | TSG |  |  |
| 324 | 47.1 | Creation of a TR | 206d? | 2003-02-07 A | 2003-11-21 A | 100% |  | 2003-02-07 | 2003-11-21 | 206d? |  | finish no earlier than 2003-11-21 | GP | 1648h | 1648h | SCSAGB-TR | David Bladsjö, Ericsson |  | Rel-6 | TSG |  |  |
| 325 | 47.2 | Stage 2 | 201d? | 2003-11-21 A | 2004-08-27 | 35% | 130.65d? | 2003-11-21 | 2004-04-23 | 111d? | 207d | finish no earlier than 2004-08-27 | GP | 1608h | 562.8h | SCSAGB-Stage2 | David Bladsjö, Ericsson |  | Rel-6 | TSG |  |  |
| 326 | 47.3 | Radio Channel Support | 146d? | 2004-02-06 | 2004-08-27 |  |  | 2004-02-06 | 2004-04-23 | 56d? | 207d | finish no earlier than 2004-08-27 | GP | 1168h |  | SCSAGB-RCS | David Bladsjö, Ericsson |  | Rel-6 | TSG |  |  |
| 327 | 47.4 | Definition of radio resource management functionality | 146d? | 2004-02-06 | 2004-08-27 |  |  | 2004-02-06 | 2004-04-23 | 56d? | 207d | finish no earlier than 2004-08-27 | GP; G2 | 2336h |  | SCSAGB-RRM | David Bladsjö, Ericsson |  | Rel-6 | TSG |  |  |
| 328 | 47.5 | PS Handover | 146d? | 2004-02-06 | 2004-08-27 |  |  | 2004-02-06 | 2004-04-23 | 56d? | 207d | finish no earlier than 2004-08-27 | GP | 1168h |  | SCSAGB-PSH | David Bladsjö, Ericsson |  | Rel-6 | TSG |  |  |
| 329 | 47.6 | Modifications to FLO | 146d? | 2004-02-06 | 2004-08-27 |  |  | 2004-02-06 | 2004-04-23 | 56d? | 207d | finish no earlier than 2004-08-27 | GP; G2 | 2336h |  | SCSAGB-FLO | David Bladsjö, Ericsson |  | Rel-6 | TSG |  |  |
| 330 | 48 | **Enhancement of dialled service for CAMEL** | 199d | 2003-03-28 A | 2003-12-31 A | 100% |  | 2003-03-28 | 2003-09-19 | 126d? |  |  | S1 | 3184h | 3184h | EDCAMEL | Craig Bishop, Samsung Electronics Research Institute |  | Rel-6 | TSG | Andrijana |  |
| 331 | 48.1 | Stages 2 and 3 | 199d | 2003-03-28 A | 2003-12-31 A | 100% |  | 2003-03-28 | 2003-09-19 | 126d |  | finish no earlier than 2003-09-19 | N2 | 1592h | 1592h |  |  |  | Rel-6 |  |  |  |
| 332 | 49 | Bandwidth and resource savings in CS networks | 273d? | 2003-06-01 A | 2004-06-16 A | 100% |  | 2003-06-23 | 2003-11-25 | 112d? |  | finish no earlier than 2004-06-16 | S2 | 2184h | 2184h | CSSAVE |  |  | Rel-6 |  |  | TR 23.977 |
| 333 | 50 | FS on (U)SIM Security Reuse by Peripheral Devices on Local Interfaces | 127d? | 2003-07-03 A | 2003-12-26 | 5% | 120.65d? | 2003-07-03 | 2003-12-26 | 127d? | 382d | finish no earlier than 2003-12-26 | S3 | 1016h | 50.8h |  | Raziq Yaqub, Toshiba America Research Inc. | ryaqub@tari.toshiba.com | Rel-6 | TSG | Maurice |  |
| 334 | 51 | **Multiple TBF in A/Gb mode** | 581d? | 2002-04-05 A | 2004-06-25 | 65% | 201.05d? | 2002-04-05 | 2004-01-30 | 476d? | 252d |  | GP; G2 | 37368h | 27408.6h | MULTBF | Gunnar Mildh, Ericsson |  | Rel-6 | TSG | Paolo |  |
| 335 | 51.1 | **Multiple TBF in A/Gb mode** | 366d? | 2002-04-05 A | 2003-08-29 A | 100% |  | 2002-04-05 | 2003-08-29 | 366d? |  |  | GP; G2 | 23424h | 23424h | MULTBF-Agbmode | Gunnar Mildh, Ericsson |  | Rel-6 | TSG |  |  |
| 336 | 51.1.1 | Multiple TBF Concept paper | 366d? | 2002-04-05 A | 2003-08-29 A | 100% |  | 2002-04-05 | 2003-08-29 | 366d? |  | finish no earlier than 2003-08-29 | GP; G2 | 5856h | 5856h |  |  |  | Rel-6 |  |  |  |
| 337 | 51.1.2 | Multiple TBF Stage 2 (43.064) CRs | 366d? | 2002-04-05 A | 2003-08-29 A | 100% |  | 2002-04-05 | 2003-08-29 | 366d? |  | finish no earlier than 2003-08-29 | GP; G2 | 5856h | 5856h |  |  |  | Rel-6 |  |  |  |
| 338 | 51.1.3 | Multiple TBF Stage 3 (44.060) CRs | 366d? | 2002-04-05 A | 2003-08-29 A | 100% |  | 2002-04-05 | 2003-08-29 | 366d? |  | finish no earlier than 2003-08-29 | GP; G2 | 5856h | 5856h |  |  |  | Rel-6 |  |  |  |
| 339 | 51.2 | Multiple TBF in A/Gb mode – MS testing | 581d? | 2002-04-05 | 2004-06-25 |  |  | 2002-04-05 | 2004-01-30 | 476d? | 252d | finish no earlier than 2004-06-25 | G3 | 4648h |  | MULTBF-Testing | Gunnar Mildh, Ericsson |  | Rel-6 | TSG | Paolo |  |
| 340 | 52 | **Alignment between the test-regimes for GERAN capable MS** | 261d? | 2003-08-29 A | 2004-08-27 | 80% | 52.2d? |  |  |  | 207d |  | G3 | 4176h | 1670.4h | ALTERE | Toubassi, Ericsson |  | Rel-6 | TSG | Michael |  |
| 341 | 52.1 | Determine the controversial test cases in the different test regimes and align them with 3GPP GERAN test specifications. Such test cases to be added to TS 51.010. | 261d? | 2003-08-29 A | 2004-08-27 | 80% | 52.2d? |  |  |  | 207d | finish no earlier than 2004-08-27 | G3 | 2088h | 1670.4h | ALTERE-TC |  |  | Rel-6 | TSG |  |  |
| 342 | 53 | Addition of U-TDOA in the CS domain | 111d? | 2003-11-21 A | 2004-04-23 A | 100% |  |  |  |  |  | finish no earlier than 2004-04-23 | GP | 888h | 888h | UTDOACS | Bob Gross, Rhys Robinson, TruePosition, Inc. | rlgross@trueposition.com | Rel-6 | TSG | Paolo |  |
| 343 | 54 | Addition of U-TDOA in the PS domain | 361d? | 2003-06-27 A | 2004-11-12 | 5% | 342.95d? |  |  |  | 152d | finish no earlier than 2004-11-12 | GP | 2888h | 144.4h | UTDOAPS | Bob Gross, Rhys Robinson, TruePosition, Inc. | rlgross@trueposition.com | Rel-6 | TSG | Paolo |  |
| 344 | 55 | **Advanced Receiver Performance** | 332d? | 2003-11-21 A | 2005-02-28 | 23% | 255.55d? |  |  |  | 76d |  | GP | 16216h | 2415.33h | ARP | Tommy Bysted, Nokia | tommy.bysted@nokia.com | Rel-6 | TSG | Paolo |  |
| 345 | 55.1 | ARP test scenarios | 201d? | 2003-11-21 A | 2004-08-27 | 45% | 110.55d? |  |  |  | 207d | finish no earlier than 2004-08-27 | GP | 1608h | 723.6h | ARP-TS | Tommy Bysted, Nokia | tommy.bysted@nokia.com | Rel-6 | TSG | Paolo |  |
| 346 | 55.2 | **ARP for GMSK modulated voice services** | 201d? | 2004-02-06 A | 2004-11-12 | 15% | 170.85d? |  |  |  | 152d |  | GP | 4824h | 482.4h | ARP-GMSK | Tommy Bysted, Nokia | tommy.bysted@nokia.com | Rel-6 | TSG | Paolo |  |
| 347 | 55.2.1 | Performance requirements in 45.005 | 201d? | 2004-02-06 A | 2004-11-12 | 15% | 170.85d? |  |  |  | 152d | finish no earlier than 2004-11-12 | GP | 1608h | 241.2h | ARP-GMSK-Perf |  |  | Rel-6 | TSG |  |  |
| 348 | 55.2.2 | Radio subsystem link control in 45.008 | 201d? | 2004-02-06 A | 2004-11-12 | 15% | 170.85d? |  |  |  | 152d | finish no earlier than 2004-11-12 | GP | 1608h | 241.2h | ARP-GMSK-LC |  |  | Rel-6 | TSG |  |  |

Notes:
- 325: Started
- 326: Not started
- 327: Not started
- 328: Not started
- 329: Not started
- 333: Approved TSG#20
- 338: Not started
- 339: Not started
- 341: Started
- 342: Completed, except for potential LMU performance specs
- 343: Started
- 345: Started
- 346: Started
- 347: Started
- 348: Started

| ID | WBS | Task | Duration | Start | Finish | Complete | Remaining | Baseline start | Baseline finish | Baseline duration | Total slack | Constraint | Resources | Work | Actual work | Text1 | Text4 | Text5 | Text6 | Text7 | Text8 | Text3 |
| --- | --- | --- | --- | --- | --- | --- | --- | --- | --- | --- | --- | --- | --- | --- | --- | --- | --- | --- | --- | --- | --- | --- |
| 349 | 55.3 | **ARP for GPRS and EGPRS MCS1-MCS4** | 201d? | 2004-02-06 A | 2004-11-12 | 10% | 180.9d? |  |  |  | 152d |  | GP | 4824h | 321.6h | ARP-GPRSE | Tommy Bysted, Nokia | tommy.bysted@nokia.com | Rel-6 | TSG | Paolo |  |
| 350 | 55.3.1 | Performance requirements in 45.005 | 201d? | 2004-02-06 A | 2004-11-12 | 10% | 180.9d? |  |  |  | 152d | finish no earlier than 2004-11-12 | GP | 1608h | 160.8h | ARP-GPRSE-Perf |  |  | Rel-6 | TSG |  |  |
| 351 | 55.3.2 | Radio subsystem link control in 45.008 | 201d? | 2004-02-06 A | 2004-11-12 | 10% | 180.9d? |  |  |  | 152d | finish no earlier than 2004-11-12 | GP | 1608h | 160.8h | ARP-GPRSE-LC |  |  | Rel-6 | TSG |  |  |
| 352 | 55.4 | ARP Capability signalling | 156d? | 2003-11-21 A | 2004-06-25 | 60% | 62.4d? |  |  |  | 252d | finish no earlier than 2004-06-25 | GP | 1248h | 748.8h | ARP-CAPSIG | Tommy Bysted, Nokia | tommy.bysted@nokia.com | Rel-6 | TSG | Paolo |  |
| 353 | 55.5 | GERAN MS Conformance test for ARP | 132d? | 2004-08-27 A | 2005-02-28 | 10% | 118.8d? |  |  |  | 76d | finish no earlier than 2005-02-28 | G3 | 1056h | 105.6h | ARP-ConfTest | Tommy Bysted, Nokia | tommy.bysted@nokia.com | Rel-6 | TSG | Michael |  |
| 354 | 56 | **Reduction of PS service interruption in Dual Transfer Mode** | 256d? | 2003-11-21 A | 2004-11-12 | 50% | 128.82d? |  |  |  | 152d |  | G2 | 5808h | 1892.18h | PSintDTM | Toby Proctor, Siemens | toby.proctor@roke.co.uk | Rel-6 | TSG | Gert |  |
| 355 | 56.1 | Use case and requirement definition | 111d? | 2003-11-21 A | 2004-04-23 A | 100% |  |  |  |  |  | finish no earlier than 2004-04-23 | G2 | 888h | 888h | PSintDTM-Req | Toby Proctor, Siemens | toby.proctor@roke.co.uk | Rel-6 | TSG | Gert |  |
| 356 | 56.2 | Performance Study of Current Procedures | 111d? | 2003-11-21 A | 2004-04-23 A | 100% |  |  |  |  |  | start no earlier than 2003-11-21 | G2 | 888h | 888h | PSintDTM-Perf | Toby Proctor, Siemens | toby.proctor@roke.co.uk | Rel-6 | TSG | Gert |  |
| 357 | 56.3 | Reduction of service interruption times and packet loss during Dual Transfer Mode and mobility procedures | 46d? | 2004-04-23 A | 2004-06-25 | 25% | 34.5d? |  |  |  | 252d | finish no earlier than 2004-06-25 | G2 | 368h | 92h | PSintDTM-Reduct | Toby Proctor, Siemens | toby.proctor@roke.co.uk | Rel-6 | TSG | Gert |  |
| 358 | 56.4 | MS Conformance testing | 101d? | 2004-06-25 | 2004-11-12 |  |  |  |  |  | 152d | finish no earlier than 2004-11-12 | G3 | 808h |  | PSintDTM-ConfMS |  |  | Rel-6 | TSG | Michael |  |
| 359 | 56.5 | BTS Conformance testing | 101d? | 2004-06-25 | 2004-11-12 |  |  |  |  |  | 152d | finish no earlier than 2004-11-12 | G3 | 808h |  | PSintDTM-ConfBTS |  |  | Rel-6 | TSG | Michael |  |
| 360 | 57 | CAMEL prepay interworking with SCUDIF | 206d | 2003-12-08 A | 2004-10-05 |  | 206d |  |  |  | 180.7d |  | N4 | 1648h |  | SCCAMEL |  |  | Rel-6 |  |  |  |
| 361 | 58 | **Circuit Switched Video and Voice Service Improvements** | 210d? | 2004-01-12 A | 2004-10-29 | 39% | 128.5d? | 2003-03-28 | 2003-09-19 | 126d | 162d |  | S1 | 8090h | 2982h | CS_VSS | John Watson, Vodafone Group |  | Rel-6 | TSG | Michael |  |
| 362 | 58.1 | Stage 1 - Requirements | 199d | 2004-01-12 A | 2004-10-14 A | 100% |  | 2004-01-12 | 2004-10-14 | 199d |  | finish no earlier than 2004-10-14 | S1 | 1592h | 1592h |  | John Watson, Vodafone Group |  | Rel-6 | TSG | Michael |  |
| 363 | 58.2 | Stage 2 Study on architecture alternatives | 155d? | 2004-01-12 A | 2004-08-13 | 80% | 31d? |  |  |  | 217d | finish no earlier than 2004-08-13 | S2 | 1240h | 992h |  |  |  |  |  |  |  |
| 364 | 58.3 | Stage 2 description on Redial | 130d? | 2004-05-03 | 2004-10-29 |  |  |  |  |  | 162d | start no earlier than 2004-05-01 | S2 | 1040h |  |  |  |  |  |  |  |  |
| 365 | 58.4 | DELETE - CN3 Part | 149.25d | 2004-01-12 | 2004-10-14 |  |  | 2004-02-20 | 2004-10-14 | 120.25d | 173d | start no earlier than 2004-01-12 | N3 | 1194h |  |  |  |  | Rel-6 | TSG | DavidB |  |
| 366 | 58.5 | GERAN2 Part | 199d | 2004-01-12 | 2004-10-14 |  |  | 2004-02-20 | 2004-02-20 | 1d | 173d | start no earlier than 2004-01-12 | G2 | 1592h |  |  |  |  | Rel-6 | TSG | Gert |  |
| 367 | 59 | **Access Class Barring and Overload Protection** | 187d? | 2004-03-15 A | 2004-11-30 | 20% | 149.15d? |  |  |  | 140d |  | S2 | 4600h | 931.14h | ACBOP | Chris Pudney, Vodafone |  |  | TSG | Sang-Ui |  |
| 368 | 59.1 | TR on Stage 2 | 187d? | 2004-03-15 A | 2004-11-30 | 42% | 108.46d? |  |  |  | 140d | finish no earlier than 2004-11-30 | S2 | 1496h | 628.32h |  |  |  |  | TSG |  |  |
| 369 | 59.2 | Extra ACBOP information in RAN | 67d? | 2004-03-15 | 2004-06-15 |  |  |  |  |  | 260d | start no earlier than 2004-03-15 | RP | 536h |  |  |  |  |  | TSG |  | 25.331 |
| 370 | 59.3 | Extra ACBOP information in GERAN | 67d? | 2004-03-15 | 2004-06-15 |  |  |  |  |  | 260d | start no earlier than 2004-03-15 | GP | 536h |  |  |  |  |  | TSG |  | 44.018 |
| 371 | 59.4 | Potential impact on Iu interface Overload functionality | 67d? | 2004-03-15 | 2004-06-15 |  |  |  |  |  | 260d | start no earlier than 2004-03-15 | RP | 536h |  |  |  |  |  | TSG |  | 25.413 |
| 372 | 60 | **Combining CS bearers with IMS** | 187d? | 2004-03-15 | 2004-11-30 |  |  |  |  |  | 140d |  | S2 | 2992h |  | CSI | Mark Watson, Nortel Networks |  |  | TSG | Sang-Ui |  |
| 373 | 60.1 | TR on Alternative Architectures for Combining CS Bearers with IMS | 187d? | 2004-03-15 | 2004-11-30 |  |  |  |  |  | 140d | finish no earlier than 2004-11-30 | S2 | 1496h |  |  |  |  |  | TSG |  |  |
| 374 | 61 | USSD message delivery and transfer to USIM | 152d? | 2004-03-18 A | 2004-10-15 | 10% | 136.8d? |  |  |  | 172d | start no earlier than 2004-03-18 | S1 | 1216h | 121.6h |  |  |  |  | TSG |  | 22.090 |

Notes:
- 349: Started
- 350: Started
- 351: Started
- 352: Started
- 353: Started
- 355: Started
- 356: Started
- 357: Started
- 358: Not started
- 359: Not started
